# Training Rollout Initiative and Plans

Schedule from MS Project, 2024-02-12 to 2024-09-17.
WillcoxPMO

## Calendars

- Standard: Mon-Fri 08:00-12:00, 13:00-17:00; Sat-Sun off.

## Resources

| Resource |
| --- |
| IT Manager |
| Soft Training Team |
| Software Update Team |
| Cabling Team |
| Stakeholders |
| Team Leaders |

## Schedule

| ID | WBS | Task | Type | Duration | Start | Finish | Predecessors | Total slack | Free slack | Resources | Work |
| --- | --- | --- | --- | --- | --- | --- | --- | --- | --- | --- | --- |
| 1 | 1 | **TRIP - Stage 1 - Project Planning** |  | 19d | 2024-02-12 | 2024-03-07 |  | 0d |  |  | 480h |
| 2 | 1.1 | Define project objectives and describe mission statement |  | 2d | 2024-02-12 | 2024-02-13 |  | 146.25d | 0d | IT Manager | 16h |
| 3 | 1.2 | Ensure total participation by training team support staff |  | 1d | 2024-02-12 | 2024-02-12 |  | 0d |  | IT Manager; Soft Training Team | 16h |
| 4 | 1.3 | **Identify Departments or End-User Community to be Trained** |  | 7d | 2024-02-13 | 2024-02-21 |  | 0d |  |  | 192h |
| 5 | 1.3.1 | Create list of target departments |  | 1d | 2024-02-14 | 2024-02-14 | 2 | 146.25d | 0d | IT Manager | 8h |
| 6 | 1.3.2 | Perform departmental training needs analysis |  | 7d | 2024-02-13 | 2024-02-21 | 3 | 0d |  | IT Manager; Soft Training Team | 112h |
| 7 | 1.3.3 | Compile results and present findings to training coordinator |  | 2d | 2024-02-16 | 2024-02-19 | 6FS-4d | 0d |  | Software Update Team | 16h |
| 8 | 1.3.4 | Prioritize training delivery according to critical need |  | 2d | 2024-02-20 | 2024-02-21 | 7 | 0d |  | Soft Training Team | 16h |
| 9 | 1.3.5 | Inform department heads of the training initiative |  | 2d | 2024-02-15 | 2024-02-16 | 5 | 151.75d |  | IT Manager | 16h |
| 10 | 1.3.6 | Determine if training can be done in-house or outsourced |  | 1.5d | 2024-02-15 | 2024-02-16 | 5 | 146.25d | 0d | IT Manager; Soft Training Team | 24h |
| 11 | 1.4 | **Seek Input from Training Vendor** |  | 6d | 2024-02-16 | 2024-02-26 |  | 146.25d |  | Stakeholders; IT Manager | 168h |
| 12 | 1.4.1 | Define vendor deliverables - can they meet our needs? |  | 1d | 2024-02-16 | 2024-02-19 | 10 | 146.25d | 0d | IT Manager; Stakeholders | 16h |
| 13 | 1.4.2 | Obtain vendor commitment to training rollout schedule |  | 3d | 2024-02-19 | 2024-02-22 | 12 | 146.25d | 0d | IT Manager | 24h |
| 14 | 1.4.3 | Review and customize training material |  | 2d | 2024-02-22 | 2024-02-26 | 12, 13 | 146.25d |  | Soft Training Team | 16h |
| 15 | 1.4.4 | Obtain approval for purchase orders to cover vendor invoices |  | 2d | 2024-02-22 | 2024-02-26 | 13 | 146.25d |  | Soft Training Team | 16h |
| 16 | 1.5 | **Perform End-User Skill Assessment** |  | 11d | 2024-02-22 | 2024-03-07 |  | 0d |  |  | 88h |
| 17 | 1.5.1 | Create a list of training recipients by department |  | 2d | 2024-02-22 | 2024-02-23 | 8 | 0d |  | Team Leaders | 16h |
| 18 | 1.5.2 | Send skill assessment forms to department heads |  | 2d | 2024-02-26 | 2024-02-27 | 17 | 0d |  | Team Leaders | 16h |
| 19 | 1.5.3 | Collect and compile results by department |  | 5d | 2024-02-28 | 2024-03-05 | 18 | 0d |  |  |  |
| 20 | 1.5.4 | Initiate end-user placement matrix |  | 3d | 2024-03-04 | 2024-03-06 | 19FS-2d | 0d |  | IT Manager | 24h |
| 21 | 1.5.5 | Finalize project budget |  | 2d | 2024-03-06 | 2024-03-07 | 19 | 137.75d | 0d | IT Manager; Stakeholders | 32h |
| 22 | 1.6 | Stage 1 - TRIP - End project initiation | milestone | 0d | 2024-03-07 | 2024-03-07 | 21 | 137.75d |  | IT Manager |  |
| 24 | 2 | **TRIP - Stage 2 - Project Commencement** |  | 14d | 2024-03-07 | 2024-03-26 |  | 0d |  |  | 408h |
| 25 | 2.1 | **Prepare Rollout Schedule and Create Awareness** |  | 12d | 2024-03-07 | 2024-03-22 |  | 0d |  |  | 328h |
| 26 | 2.1.1 | Determine course dates, start and end times, and locations |  | 3d | 2024-03-07 | 2024-03-11 | 20 | 0d |  | IT Manager; Software Update Team; Team Leaders | 72h |
| 27 | 2.1.2 | Post course outlines and schedule on corporate intranet |  | 1d | 2024-03-12 | 2024-03-13 | 26FS+0.5d | 129.25d | 0d | Team Leaders | 8h |
| 28 | 2.1.3 | Establish support through help desk for post-training questions |  | 1d | 2024-03-12 | 2024-03-12 | 26 | 134.75d |  | Soft Training Team | 8h |
| 29 | 2.1.4 | Reserve training rooms |  | 1d | 2024-03-12 | 2024-03-12 | 26 | 134.75d |  | IT Manager | 8h |
| 30 | 2.1.5 | Coordinate with information technology team for optimal workstation and equipment performance |  | 1d | 2024-03-13 | 2024-03-14 | 27 | 133.25d |  | IT Manager; Software Update Team | 16h |
| 31 | 2.1.6 | Order training manuals and necessary material |  | 7d | 2024-03-12 | 2024-03-20 | 26 | 128.75d |  | IT Manager | 56h |

Notes:
- 11: Can be skipped if instructors and training are done in-house.
- 16: Optimal results begin with assessments of professional skills that identify gaps, and their causes that prevent an organization from achieving its highest goals.
- 18: Department heads, in turn, request that their own staff complete and return the skill assessment forms.
- 20: Use the matrix to place each user in the proper training session....
- 24: Assumption:...

| ID | WBS | Task | Type | Duration | Start | Finish | Predecessors | Total slack | Free slack | Constraint | Resources | Work |
| --- | --- | --- | --- | --- | --- | --- | --- | --- | --- | --- | --- | --- |
| 32 | 2.1.7 | **Marketing Strategy** |  | 9d | 2024-03-12 | 2024-03-22 |  | 0d |  |  | IT Manager | 160h |
| 33 | 2.1.7.1 | Order promotional material |  | 7d | 2024-03-12 | 2024-03-20 | 26 | 0d |  |  | IT Manager | 56h |
| 34 | 2.1.7.2 | Create posters and place them in high-traffic areas |  | 4d | 2024-03-19 | 2024-03-22 | 33FS-2d | 0d |  |  | IT Manager | 32h |
| 35 | 2.1.7.3 | E-mail invitation to participants |  | 1d | 2024-03-19 | 2024-03-19 | 34SS | 128.75d | 0d |  |  |  |
| 36 | 2.1.7.4 | Arrange for catering of meals and refreshments |  | 1d | 2024-03-20 | 2024-03-20 | 35 | 128.75d |  |  |  |  |
| 37 | 2.2 | **Training Sessions Registration** |  | 5d | 2024-03-19 | 2024-03-25 |  | 0d |  |  | Team Leaders | 80h |
| 38 | 2.2.1 | Enroll users who registered via corporate intranet |  | 2d | 2024-03-19 | 2024-03-20 | 34SS | 0d |  |  |  |  |
| 39 | 2.2.2 | Send out confirmations to these registration |  | 1d | 2024-03-21 | 2024-03-21 | 38 | 2d |  |  | Software Update Team; Team Leaders | 16h |
| 40 | 2.2.3 | Send out prework requirements |  | 2d | 2024-03-19 | 2024-03-20 | 38SS | 3d |  |  | Team Leaders | 16h |
| 41 | 2.2.4 | Monitor cancellations and late requests for training |  | 1d | 2024-03-25 | 2024-03-25 | 38FS+2d | 0d |  |  | Software Update Team | 8h |
| 42 | 2.3 | **Schedule Instructors** |  | 3d | 2024-03-13 | 2024-03-18 |  | 131.25d |  |  |  |  |
| 43 | 2.3.1 | In-house instructors |  | 1d | 2024-03-13 | 2024-03-14 | 27 | 133.25d |  |  |  |  |
| 44 | 2.3.2 | Outsourced instructors |  | 3d | 2024-03-13 | 2024-03-18 | 27 | 131.25d |  |  |  |  |
| 45 | 2.4 | **Courseware Evaluations** |  | 3d | 2024-03-15 | 2024-03-20 |  | 129.25d |  |  |  |  |
| 46 | 2.4.1 | Reuse or build an end-user course evaluation form (online or paper) |  | 2d | 2024-03-15 | 2024-03-19 | 27FS+2d | 130.25d |  |  |  |  |
| 47 | 2.4.2 | Reuse or build an special feedback form for instructors |  | 2d | 2024-03-18 | 2024-03-20 | 27FS+3d | 129.25d |  |  |  |  |
| 48 | 2.5 | Stage 2 - TRIP - End project commencement | milestone | 0d | 2024-03-26 | 2024-03-26 | 37FS+1d | 0d |  |  |  |  |
| 50 | 3 | **TRIP - Stage 3 - Project Implementation and Control** |  | 12.75d | 2024-03-29 | 2024-04-16 |  | 0d |  |  |  |  |
| 51 | 3.1 | Conduct training and track attendance |  | 9.25d | 2024-03-29 | 2024-04-11 | 48FS+2d | 0d |  |  |  |  |
| 52 | 3.2 | **Daily Conference Call (Hold Daily Call to Address Issues)** |  | 9.25d | 2024-03-29 | 2024-04-11 |  | 113.5d |  |  |  |  |
| 53 | 3.2.1 | Call 1 |  | 1h | 2024-03-29 | 2024-03-29 | 51SS | 113.5d | 0d | start no earlier than 2020-03-09 |  |  |
| 54 | 3.2.2 | Call 2 |  | 1h | 2024-04-01 | 2024-04-01 | 53FS+1d | 113.5d | 0d | start no earlier than 2020-03-10 |  |  |
| 55 | 3.2.3 | Call 3 |  | 1h | 2024-04-02 | 2024-04-02 | 54FS+1d | 113.5d | 0d | start no earlier than 2020-03-11 |  |  |
| 56 | 3.2.4 | Call 4 |  | 1h | 2024-04-03 | 2024-04-03 | 55FS+1d | 113.5d | 0d | start no earlier than 2020-03-12 |  |  |
| 57 | 3.2.5 | Call 5 |  | 1h | 2024-04-04 | 2024-04-04 | 56FS+1d | 113.5d | 0d | start no earlier than 2020-03-13 |  |  |
| 58 | 3.2.6 | Call 6 |  | 1h | 2024-04-05 | 2024-04-05 | 57FS+1d | 113.5d | 0d | start no earlier than 2020-03-16 |  |  |
| 59 | 3.2.7 | Call 7 |  | 1h | 2024-04-08 | 2024-04-08 | 58FS+1d | 113.5d | 0d | start no earlier than 2020-03-17 |  |  |
| 60 | 3.2.8 | Call 8 |  | 1h | 2024-04-09 | 2024-04-09 | 59FS+1d | 113.5d | 0d | start no earlier than 2020-03-18 |  |  |
| 61 | 3.2.9 | Call 9 |  | 1h | 2024-04-10 | 2024-04-10 | 60 | 113.5d | 0d | start no earlier than 2020-03-19 |  |  |
| 62 | 3.2.10 | Call 10 |  | 1h | 2024-04-11 | 2024-04-11 | 61FS+1d | 113.5d |  | start no earlier than 2020-03-20 |  |  |
| 63 | 3.3 | Collect feedback and compile results |  | 2.5d | 2024-04-09 | 2024-04-11 | 51FS-2d | 0d |  |  |  |  |
| 64 | 3.4 | Determine need for make up training |  | 1.5d | 2024-04-11 | 2024-04-12 | 51 | 112d |  |  |  |  |
| 65 | 3.5 | Update department heads with training results |  | 2d | 2024-04-11 | 2024-04-15 | 63 | 0d |  |  |  |  |
| 66 | 3.6 | Issue certificates of completion to participants |  | 1d | 2024-04-15 | 2024-04-16 | 65 | 0d |  |  |  |  |
| 67 | 3.7 | Stage 3 - TRIP - End project implementation and control | milestone | 0d | 2024-04-16 | 2024-04-16 | 66 | 0d |  |  |  |  |

Notes:
- 33: Promotional material can include custom notepads, pens, mouse pads, etc.
- 38: Enrollment and confirmations can be fully automated if done through corporate intranet....
- 40: After skills assessments are collected, there may be a need to contact individual users and ask them to perform some prep work or prework prior to their participation in training. This is to ensure that such users have satisfied the necessary prerequisite
- 41: There may be a need for makeup sessions if a sufficient number of absent users require them....
- 47: This form is usually used to collect feedback from instructors on the quality of material, room setup, workstation performance, specific user issues, specific software issues and specific vendor issues (if applicable)....
- 50: Assumption:...
- 52: Conference call performed at the end of the training day. Right-click this task and click Task Information to adjust the various options.
- 53: Conference call performed at the end of the training day. Right-click this task and click Task Information to adjust the various options.
- 54: Conference call performed at the end of the training day. Right-click this task and click Task Information to adjust the various options.
- 55: Conference call performed at the end of the training day. Right-click this task and click Task Information to adjust the various options.
- 56: Conference call performed at the end of the training day. Right-click this task and click Task Information to adjust the various options.
- 57: Conference call performed at the end of the training day. Right-click this task and click Task Information to adjust the various options.
- 58: Conference call performed at the end of the training day. Right-click this task and click Task Information to adjust the various options.
- 59: Conference call performed at the end of the training day. Right-click this task and click Task Information to adjust the various options.
- 60: Conference call performed at the end of the training day. Right-click this task and click Task Information to adjust the various options.
- 61: Conference call performed at the end of the training day. Right-click this task and click Task Information to adjust the various options.
- 62: Conference call performed at the end of the training day. Right-click this task and click Task Information to adjust the various options.
- 63: Course evaluations can be fully automated so that users complete an online form at the end of each session; this makes compiling results much easier. However, allow more time if evaluations are completed via paper forms....
- 66: When the rollout is complete, certificates of completion are sent to department heads; they are in turn given out to the participants based on specific departmental procedures (such as updating employment records or send to regulatory agencies for require

| ID | WBS | Task | Type | Duration | Start | Finish | Predecessors | Total slack |
| --- | --- | --- | --- | --- | --- | --- | --- | --- |
| 69 | 4 | **TRIP - Stage 4 - Project Close Out and Conclusion** |  | 108d | 2024-04-18 | 2024-09-17 |  | 0d |
| 70 | 4.1 | **Performance measurement through post-training review of deliverables** |  | 8d | 2024-04-18 | 2024-04-30 |  | 0d |
| 71 | 4.1.1 | Discuss evaluations, results, and process improvements with training team support staff |  | 1d | 2024-04-18 | 2024-04-19 | 67FS+2d | 0d |
| 72 | 4.1.2 | Create a list of best practices and FAQ for future training endeavors |  | 3d | 2024-04-19 | 2024-04-24 | 71 | 0d |
| 73 | 4.1.3 | Discuss results with vendor for any improvements |  | 2d | 2024-04-24 | 2024-04-26 | 71, 72 | 0d |
| 74 | 4.1.4 | Identify issues that were problems and improve them |  | 2d | 2024-04-26 | 2024-04-30 | 71, 72, 73 | 0d |
| 75 | 4.2 | **Conduct Return On Investment (ROI) Research** |  | 10d | 2024-09-03 | 2024-09-17 |  | 0d |
| 76 | 4.2.1 | Send ROI forms to participants and department heads |  | 2d | 2024-09-03 | 2024-09-05 | 70FS+90d | 0d |
| 77 | 4.2.2 | Measure ROI according to established parameters |  | 5d | 2024-09-04 | 2024-09-11 | 76FS-1d | 0d |
| 78 | 4.2.3 | Compile results and present findings to department heads and HR and training managers |  | 4d | 2024-09-11 | 2024-09-17 | 77 | 0d |
| 79 | 4.3 | Stage 4 - TRIP - End project close out and conclusion | milestone | 0d | 2024-09-17 | 2024-09-17 | 78 | 0d |
| 80 | 5 | Party!! For training team support staff (and vendor staff) |  | 1d | 2024-04-16 | 2024-04-17 | 67 | 109d |

Notes:
- 75: Typically done three months after the completion of the training rollout.
- 76: The goal is to determine if they are using and applying what they learned. A standard training ROI form is used....
