# Compliance and Technology Options

Schedule from MS Project, 2024-02-12 to 2024-04-30.
Willcox PMO

## Calendars

- Standard: Mon-Fri 08:00-12:00, 13:00-17:00; Sat-Sun off.

## Resources

| Resource |
| --- |
| External Auditing |
| Internal Audit Director |
| CFO |
| Accounting |
| Compliance Team |
| IT Network & Infrastructure Team |
| IT Applications Team |
| IT Director / Manager |
| Cabling Team |
| AD DS Team |

## Schedule

| ID | WBS | Task | Type | Duration | Start | Finish | Predecessors | Total slack | Resources | Work |
| --- | --- | --- | --- | --- | --- | --- | --- | --- | --- | --- |
| 1 | 1 | **Network Review Preparation** |  | 9d? | 2024-02-12 | 2024-02-22 |  | 0d |  | 128h |
| 2 | 1.1 | Meeting with the external audit firm |  | 2d? | 2024-02-12 | 2024-02-13 |  | 0d | IT Applications Team [25%]; IT Director / Manager [25%] | 8h |
| 3 | 1.2 | Define compliance review roles and responsibilities |  | 1d | 2024-02-14 | 2024-02-14 | 2 | 0d | External Auditing; Internal Audit Director; CFO | 24h |
| 4 | 1.3 | Define compliance review and decision processes |  | 3d | 2024-02-14 | 2024-02-16 | 3SS | 0d | Cabling Team; IT Applications Team | 48h |
| 5 | 1.4 | Create compliance review project plan |  | 3d? | 2024-02-19 | 2024-02-21 | 4 | 0d | Cabling Team | 24h |
| 6 | 1.5 | Conduct kickoff meeting |  | 1d? | 2024-02-22 | 2024-02-22 | 5 | 0d | External Auditing; Internal Audit Director; CFO | 24h |
| 7 | 1.6 | Network Review & Preparation Completed | milestone | 0d | 2024-02-22 | 2024-02-22 | 6 | 47.5d |  |  |
| 9 | 2 | **Initiation and Scope** |  | 4.5d? | 2024-02-23 | 2024-02-29 |  | 0d |  | 48h |
| 10 | 2.1 | Determine the systems and processes that are in scope |  | 0.5d? | 2024-02-23 | 2024-02-23 | 4, 6 | 0d | Accounting; Compliance Team | 8h |
| 11 | 2.2 | Build communications plan for project participants and stakeholders |  | 1d? | 2024-02-23 | 2024-02-26 | 10 | 0d | Compliance Team | 8h |
| 12 | 2.3 | Identify training requirements for new project participants |  | 1d? | 2024-02-26 | 2024-02-27 | 11 | 0d | IT Applications Team | 8h |
| 13 | 2.4 | Define project plan, key milestones, budget, and key project participants |  | 1d? | 2024-02-27 | 2024-02-28 | 12 | 0d | IT Applications Team; IT Director / Manager | 16h |
| 14 | 2.5 | Define project progress reporting and structure for senior management |  | 1d? | 2024-02-28 | 2024-02-29 | 13 | 0d | Compliance Team | 8h |
| 15 | 2.6 | Project Initiation Complete | milestone | 0d | 2024-02-29 | 2024-02-29 | 14 | 0d |  |  |
| 17 | 3 | **Review and Identify Improvement Opportunities** |  | 23d? | 2024-02-29 | 2024-04-02 |  | 0d |  | 632.16h |
| 18 | 3.1 | **Perform Risk Assessment** |  | 3d? | 2024-02-29 | 2024-03-05 |  | 0d |  | 24h |
| 19 | 3.1.1 | Review and confirm risk factors |  | 1d? | 2024-02-29 | 2024-03-01 | 15 | 0d | Compliance Team | 8h |
| 20 | 3.1.2 | Validate probability and impact of risk factors |  | 1d? | 2024-03-01 | 2024-03-04 | 19 | 0d | Compliance Team | 8h |
| 21 | 3.1.3 | Estimate and validate size and complexity of risk factors |  | 1d? | 2024-03-04 | 2024-03-05 | 20 | 0d | Compliance Team | 8h |
| 22 | 3.2 | **Identify Significant Accounts and Internal Controls** |  | 1d? | 2024-03-05 | 2024-03-06 |  | 0d | AD DS Team | 24h |
| 23 | 3.2.1 | Identify and validate application controls over the initiating, recording, processing, and reporting |  | 1d? | 2024-03-05 | 2024-03-06 | 21 | 0d | Compliance Team; AD DS Team | 16h |
| 24 | 3.3 | **Confirm General IT Controls** |  | 2d? | 2024-03-06 | 2024-03-08 |  | 0d |  | 184h |
| 25 | 3.3.1 | Review Security Policies and Procedures |  | 1d? | 2024-03-06 | 2024-03-07 | 23 | 0d | IT Network & Infrastructure Team; Compliance Team | 16h |
| 26 | 3.3.2 | **Review Change Management Policies and Procedures** |  | 1d? | 2024-03-06 | 2024-03-07 |  | 0d |  | 48h |
| 27 | 3.3.2.1 | Review version management/release management procedures |  | 1d? | 2024-03-06 | 2024-03-07 | 25SS | 0d | IT Network & Infrastructure Team; Compliance Team; IT Applications Team | 24h |
| 28 | 3.3.2.2 | Review source code/document version control procedures |  | 1d? | 2024-03-06 | 2024-03-07 | 25SS | 0d | IT Network & Infrastructure Team; Compliance Team; IT Applications Team | 24h |
| 29 | 3.3.3 | Review Disaster Recovery Procedures |  | 1d? | 2024-03-06 | 2024-03-07 | 25SS | 0d | Compliance Team; IT Network & Infrastructure Team | 16h |
| 30 | 3.3.4 | Review Backup and Recovery Procedures |  | 1d? | 2024-03-06 | 2024-03-07 | 25SS | 0d | Compliance Team; IT Network & Infrastructure Team | 16h |
| 31 | 3.3.5 | Review Service-Level Agreement Policies |  | 1d? | 2024-03-06 | 2024-03-07 | 25SS | 0d | IT Network & Infrastructure Team; Compliance Team; IT Applications Team; IT Director / Manager | 32h |
| 32 | 3.3.6 | Review Application Development and Coding Standards/Review Procedures |  | 1d? | 2024-03-06 | 2024-03-07 | 25SS | 0d | IT Applications Team; Compliance Team | 16h |
| 33 | 3.3.7 | Review Testing Policies and Procedures |  | 1d? | 2024-03-06 | 2024-03-07 | 25SS | 0d | IT Applications Team; Compliance Team | 16h |
| 34 | 3.3.8 | Review QA procedures |  | 1d? | 2024-03-06 | 2024-03-07 | 25SS | 0d | IT Applications Team; Compliance Team | 16h |
| 35 | 3.3.9 | Summarize Improvement Opportunities Findings |  | 1d? | 2024-03-07 | 2024-03-08 | 25, 27, 28, 29, 30, 31, 32, 34, 33 | 0d | Compliance Team | 8h |

Notes:
- 2: Subject of Meeting:...
- 5: ...
- 6: Subject of Meeting:...

| ID | WBS | Task | Type | Duration | Start | Finish | Predecessors | Total slack | Resources | Work |
| --- | --- | --- | --- | --- | --- | --- | --- | --- | --- | --- |
| 36 | 3.4 | **Confirm Control Design** |  | 3d? | 2024-03-08 | 2024-03-13 |  | 0d |  | 64h |
| 37 | 3.4.1 | Identify policies and procedures |  | 1d? | 2024-03-08 | 2024-03-11 | 35 | 0d | Compliance Team; Accounting | 16h |
| 38 | 3.4.2 | Review narratives and flowcharts |  | 1d? | 2024-03-11 | 2024-03-12 | 37 | 0d | Compliance Team; Accounting | 16h |
| 39 | 3.4.3 | Review system configuration documentation |  | 1d | 2024-03-11 | 2024-03-12 | 38SS | 0d | Compliance Team [200%]; IT Applications Team [200%] | 32h |
| 40 | 3.4.4 | Validate internal control checkpoints and processes |  | 1d? | 2024-03-12 | 2024-03-13 | 39 | 0d |  |  |
| 41 | 3.5 | **Evaluate Operational Effectiveness** |  | 3d? | 2024-03-13 | 2024-03-18 |  | 0d |  | 56.16h |
| 42 | 3.5.1 | Identify/confirm labor-intensive and cost-inefficient internal controls |  | 1d | 2024-03-13 | 2024-03-14 | 40 | 0d | Compliance Team [13%]; Accounting [13%]; CFO [13%]; IT Director / Manager [13%]; Internal Audit Director [50%] | 8.16h |
| 43 | 3.5.2 | Prioritize inefficiencies - ongoing costs/internal control risks/cost and efficiency impacts |  | 1d? | 2024-03-14 | 2024-03-15 | 42 | 0d | Internal Audit Director; Compliance Team; CFO | 24h |
| 44 | 3.5.3 | Develop cost estimates and efforts for prioritized improvement |  | 1d? | 2024-03-15 | 2024-03-18 | 43 | 0d | CFO; Internal Audit Director; Compliance Team | 24h |
| 45 | 3.6 | **Finalize Cost/Benefit Analyses** |  | 11d? | 2024-03-18 | 2024-04-02 |  | 0d |  | 280h |
| 46 | 3.6.1 | Group improvements opportunities into technology improvement projects |  | 1d? | 2024-03-18 | 2024-03-19 | 44 | 0d | CFO; Internal Audit Director; Compliance Team; IT Director / Manager; Accounting | 40h |
| 47 | 3.6.2 | Develop cost/benefit analyses |  | 1d? | 2024-03-19 | 2024-03-20 | 46 | 0d | CFO; Internal Audit Director; Compliance Team; IT Director / Manager; Accounting | 40h |
| 48 | 3.6.3 | Develop future state scenarios and opportunity savings |  | 1d? | 2024-03-20 | 2024-03-21 | 47 | 0d | CFO; Internal Audit Director; Compliance Team; IT Director / Manager; Accounting | 40h |
| 49 | 3.6.4 | Identify gaps |  | 1d? | 2024-03-21 | 2024-03-22 | 48 | 0d | CFO; Internal Audit Director; Compliance Team; IT Director / Manager; Accounting | 40h |
| 50 | 3.6.5 | Identify project risks and impacts of doing nothing |  | 5d? | 2024-03-22 | 2024-03-29 | 49 | 0d | Compliance Team | 40h |
| 51 | 3.6.6 | Identify additional key resources and information sources |  | 1d? | 2024-03-29 | 2024-04-01 | 50 | 0d | CFO; Internal Audit Director; Compliance Team; IT Director / Manager; Accounting | 40h |
| 52 | 3.6.7 | Validate scope, participants and efforts |  | 1d? | 2024-04-01 | 2024-04-02 | 51 | 0d | CFO; Internal Audit Director; Compliance Team; IT Director / Manager; Accounting | 40h |
| 53 | 3.7 | Improvement Design Complete | milestone | 0d | 2024-04-02 | 2024-04-02 | 52 | 20d |  |  |
| 55 | 4 | **Control Design** |  | 9d? | 2024-04-02 | 2024-04-15 |  | 0d |  | 176h |
| 56 | 4.1 | Project kickoff meeting |  | 1d? | 2024-04-02 | 2024-04-03 | 52 | 0d | Compliance Team; IT Applications Team | 16h |
| 57 | 4.2 | Design new systems and cross-reference to related internal controls |  | 1d? | 2024-04-03 | 2024-04-04 | 56 | 0d | IT Applications Team; Compliance Team | 16h |
| 58 | 4.3 | **Identify technologies that will be implemented** |  | 1d? | 2024-04-04 | 2024-04-05 |  | 0d |  | 48h |
| 59 | 4.3.1 | Identify data capture and editing systems |  | 1d? | 2024-04-04 | 2024-04-05 | 57 | 0d | IT Applications Team; Compliance Team | 16h |
| 60 | 4.3.2 | Identify logging and monitoring systems |  | 1d? | 2024-04-04 | 2024-04-05 | 59SS | 0d | IT Applications Team; Compliance Team | 16h |
| 61 | 4.3.3 | Identify analysis and reporting systems |  | 1d? | 2024-04-04 | 2024-04-05 | 59SS | 0d | IT Applications Team; Compliance Team | 16h |
| 62 | 4.4 | Design necessary process changes |  | 1d? | 2024-04-05 | 2024-04-08 | 59, 60, 61 | 0d | IT Applications Team; Compliance Team | 16h |
| 63 | 4.5 | Create policies, standards, and procedures |  | 1d? | 2024-04-08 | 2024-04-09 | 62 | 0d | IT Applications Team; Compliance Team | 16h |
| 64 | 4.6 | Communicate changes that will required |  | 1d? | 2024-04-09 | 2024-04-10 | 63 | 0d | IT Applications Team; Compliance Team | 16h |
| 65 | 4.7 | Identify appropriate frequency of control |  | 1d? | 2024-04-10 | 2024-04-11 | 64 | 0d | IT Applications Team; Compliance Team | 16h |
| 66 | 4.8 | Finalize design |  | 1d? | 2024-04-11 | 2024-04-12 | 65 | 0d | IT Applications Team; Compliance Team | 16h |
| 67 | 4.9 | Obtain approvals needed (SOX Compliance/Management) |  | 1d? | 2024-04-12 | 2024-04-15 | 66 | 0d | IT Applications Team; Compliance Team | 16h |
| 68 | 4.10 | Control Design Complete | milestone | 0d | 2024-04-15 | 2024-04-15 | 67 | 0d | IT Applications Team; Compliance Team |  |

| ID | WBS | Task | Type | Duration | Start | Finish | Predecessors | Total slack | Resources | Work |
| --- | --- | --- | --- | --- | --- | --- | --- | --- | --- | --- |
| 70 | 5 | **Development** |  | 3d? | 2024-04-15 | 2024-04-18 |  | 0d |  | 48h |
| 71 | 5.1 | Develop/implement redesigned systems and/or controls |  | 1d? | 2024-04-15 | 2024-04-16 | 68 | 0d | IT Applications Team; Compliance Team | 16h |
| 72 | 5.2 | Re-communicate all changes to all impacted groups |  | 1d? | 2024-04-16 | 2024-04-17 | 71 | 0d | IT Applications Team; Compliance Team | 16h |
| 73 | 5.3 | Validate internal controls maintained and/or improved |  | 1d? | 2024-04-17 | 2024-04-18 | 72 | 0d | IT Applications Team; Compliance Team | 16h |
| 74 | 5.4 | Development complete | milestone | 0d | 2024-04-18 | 2024-04-18 | 73 | 0d |  |  |
| 76 | 6 | **Testing** |  | 4d? | 2024-04-18 | 2024-04-24 |  | 0d |  | 32h |
| 77 | 6.1 | Validate control effectiveness |  | 1d? | 2024-04-18 | 2024-04-19 | 74 | 0d | IT Applications Team | 8h |
| 78 | 6.2 | Document test cases/results in detailed test plans and summaries |  | 1d? | 2024-04-19 | 2024-04-22 | 77 | 0d | IT Applications Team | 8h |
| 79 | 6.3 | Validate improvement and/or remediation actions accomplished |  | 1d? | 2024-04-22 | 2024-04-23 | 78 | 0d | IT Applications Team | 8h |
| 80 | 6.4 | Document testing results |  | 1d? | 2024-04-23 | 2024-04-24 | 79 | 0d | IT Applications Team | 8h |
| 81 | 6.5 | Testing complete | milestone | 0d | 2024-04-24 | 2024-04-24 | 80 | 0d |  |  |
| 83 | 7 | **Implement** |  | 4d? | 2024-04-24 | 2024-04-30 |  | 0d |  | 112h |
| 84 | 7.1 | Update procedures and control documentation |  | 1d? | 2024-04-24 | 2024-04-25 | 81 | 0d | IT Applications Team; IT Network & Infrastructure Team; Accounting | 24h |
| 85 | 7.2 | Implement system changes |  | 1d? | 2024-04-25 | 2024-04-26 | 84 | 0d | IT Applications Team; IT Network & Infrastructure Team; Accounting | 24h |
| 86 | 7.3 | Monitor results and improvements |  | 1d? | 2024-04-26 | 2024-04-29 | 85 | 0d | Accounting; IT Applications Team; IT Network & Infrastructure Team; Compliance Team | 32h |
| 87 | 7.4 | Document results and summarize to senior management |  | 1d? | 2024-04-29 | 2024-04-30 | 86 | 0d | Accounting; IT Applications Team; IT Network & Infrastructure Team; Compliance Team | 32h |
| 88 | 7.5 | Implementation complete | milestone | 0d | 2024-04-30 | 2024-04-30 | 87 | 0d |  |  |
