# Network Development Plan

Schedule from MS Project, 2024-01-03 to 2024-05-15.
Willcox PMO

## Calendars

- Standard: Mon-Fri 08:00-12:00, 13:00-17:00; Sat-Sun off.

## Resources

| Resource |
| --- |
| Management |
| Project Manager |
| Analyst |
| Developer |
| Testers |
| Trainers |
| Technical Communicators |
| Deployment Team |
| Network Analyst |

## Schedule

| ID | WBS | Task | Type | Duration | Start | Finish | Predecessors | Total slack | Resources | Work |
| --- | --- | --- | --- | --- | --- | --- | --- | --- | --- | --- |
| 1 | 1 | **Scope** |  | 3.5d | 2024-01-03 | 2024-01-08 |  | 0d |  | 28h |
| 2 | 1.1 | Determine network project scope |  | 4h | 2024-01-03 | 2024-01-03 |  | 0d | Project Manager | 4h |
| 3 | 1.2 | Secure upgrade funding |  | 1d | 2024-01-03 | 2024-01-04 | 2 | 0d | Management | 8h |
| 4 | 1.3 | Define preliminary resources |  | 1d | 2024-01-04 | 2024-01-05 | 3 | 0d | Project Manager | 8h |
| 5 | 1.4 | Secure core resources |  | 1d | 2024-01-05 | 2024-01-08 | 4 | 0d | Project Manager | 8h |
| 6 | 1.5 | Scope complete | milestone | 0d | 2024-01-08 | 2024-01-08 | 5 | 0d |  |  |
| 8 | 2 | **Analysis Network Upgrade Requirements** |  | 14d | 2024-01-08 | 2024-01-26 |  | 0d |  | 120h |
| 9 | 2.1 | Conduct requirements analysis |  | 5d | 2024-01-08 | 2024-01-15 | 6 | 0d | Network Analyst | 40h |
| 10 | 2.2 | Draft preliminary network specifications |  | 3d | 2024-01-15 | 2024-01-18 | 9 | 0d | Network Analyst | 24h |
| 11 | 2.3 | Develop preliminary budget |  | 2d | 2024-01-18 | 2024-01-22 | 10 | 0d | Project Manager | 16h |
| 12 | 2.4 | Review network specifications/budget with team |  | 4h | 2024-01-22 | 2024-01-22 | 11 | 0d | Project Manager; Analyst | 8h |
| 13 | 2.5 | Incorporate feedback on network specifications |  | 1d | 2024-01-23 | 2024-01-23 | 12 | 0d | Network Analyst | 8h |
| 14 | 2.6 | Develop delivery timeline |  | 1d | 2024-01-24 | 2024-01-24 | 13 | 0d | Project Manager | 8h |
| 15 | 2.7 | Obtain approvals to proceed (concept, timeline, budget) |  | 4h | 2024-01-25 | 2024-01-25 | 14 | 0d | Management; Project Manager | 8h |
| 16 | 2.8 | Secure required resources |  | 1d | 2024-01-25 | 2024-01-26 | 15 | 0d | Project Manager | 8h |
| 17 | 2.9 | Analysis complete | milestone | 0d | 2024-01-26 | 2024-01-26 | 16 | 0d |  |  |
| 19 | 3 | **Design** |  | 14.5d | 2024-01-26 | 2024-02-15 |  | 0d |  | 120h |
| 20 | 3.1 | Review preliminary network specifications |  | 2d | 2024-01-26 | 2024-01-30 | 17 | 0d | Analyst | 16h |
| 21 | 3.2 | Develop functional specifications |  | 5d | 2024-01-30 | 2024-02-06 | 20 | 0d | Analyst | 40h |
| 22 | 3.3 | Develop prototype based on functional specifications |  | 4d | 2024-02-06 | 2024-02-12 | 21 | 0d | Analyst | 32h |
| 23 | 3.4 | Review functional specifications |  | 2d | 2024-02-12 | 2024-02-14 | 22 | 0d | Management | 16h |
| 24 | 3.5 | Incorporate feedback into functional specifications |  | 1d | 2024-02-14 | 2024-02-15 | 23 | 0d | Management | 8h |
| 25 | 3.6 | Obtain approval to proceed |  | 4h | 2024-02-15 | 2024-02-15 | 24 | 0d | Management; Project Manager | 8h |
| 26 | 3.7 | Design complete | milestone | 0d | 2024-02-15 | 2024-02-15 | 25 | 0d |  |  |

| ID | WBS | Task | Type | Duration | Start | Finish | Predecessors | Total slack | Free slack | Resources | Work |
| --- | --- | --- | --- | --- | --- | --- | --- | --- | --- | --- | --- |
| 28 | 4 | **Development** |  | 21.75d | 2024-02-16 | 2024-03-18 |  | 0d |  |  | 264h |
| 29 | 4.1 | Review functional specifications |  | 1d | 2024-02-16 | 2024-02-16 | 26 | 0d |  | Developer | 8h |
| 30 | 4.2 | Identify modular/tiered design parameters |  | 1d | 2024-02-19 | 2024-02-19 | 29 | 0d |  | Developer | 8h |
| 31 | 4.3 | Assign development staff |  | 1d | 2024-02-20 | 2024-02-20 | 30 | 0d |  | Developer | 8h |
| 32 | 4.4 | Develop code |  | 15d | 2024-02-21 | 2024-03-12 | 31 | 0d |  | Developer | 120h |
| 33 | 4.5 | Developer testing (primary debugging) |  | 15d | 2024-02-26 | 2024-03-18 | 32FS-11.25d | 0d |  | Developer | 120h |
| 34 | 4.6 | Development complete | milestone | 0d | 2024-03-18 | 2024-03-18 | 33 | 0d |  |  |  |
| 36 | 5 | **Testing** |  | 48.75d | 2024-02-16 | 2024-04-24 |  | 15d |  |  | 280h |
| 37 | 5.1 | Develop unit test plans using network specifications |  | 4d | 2024-02-16 | 2024-02-21 | 26 | 17.75d |  | Testers | 32h |
| 38 | 5.2 | Develop integration test plans using product specifications |  | 4d | 2024-02-16 | 2024-02-21 | 26 | 59.75d |  | Testers | 32h |
| 39 | 5.3 | **Unit Testing** |  | 15d | 2024-03-18 | 2024-04-08 |  | 0d |  |  | 120h |
| 40 | 5.3.1 | Review network security |  | 5d | 2024-03-18 | 2024-03-25 | 37, 34 | 0d |  | Testers | 40h |
| 41 | 5.3.2 | Test components to network specifications |  | 2d | 2024-03-25 | 2024-03-27 | 34, 40 | 0d |  | Testers | 16h |
| 42 | 5.3.3 | Identify anomalies to network specifications |  | 3d | 2024-03-27 | 2024-04-01 | 41 | 0d |  | Testers | 24h |
| 43 | 5.3.4 | Upgrade devices |  | 3d | 2024-04-01 | 2024-04-04 | 42 | 0d |  | Testers | 24h |
| 44 | 5.3.5 | Re-test network for bandwidth |  | 2d | 2024-04-04 | 2024-04-08 | 43 | 0d |  | Testers | 16h |
| 45 | 5.3.6 | Network testing complete | milestone | 0d | 2024-04-08 | 2024-04-08 | 44 | 0d |  |  |  |
| 46 | 5.4 | **Integration Testing** |  | 12d | 2024-04-08 | 2024-04-24 |  | 0d |  |  | 96h |
| 47 | 5.4.1 | Test module integration |  | 5d | 2024-04-08 | 2024-04-15 | 45 | 0d |  | Testers | 40h |
| 48 | 5.4.2 | Identify anomalies to specifications |  | 2d | 2024-04-15 | 2024-04-17 | 47 | 0d |  | Testers | 16h |
| 49 | 5.4.3 | Modify network |  | 3d | 2024-04-17 | 2024-04-22 | 48 | 0d |  | Testers | 24h |
| 50 | 5.4.4 | Re-test modified network |  | 2d | 2024-04-22 | 2024-04-24 | 49 | 0d |  | Testers | 16h |
| 51 | 5.4.5 | Integration testing complete | milestone | 0d | 2024-04-24 | 2024-04-24 | 50 | 0d |  |  |  |
| 53 | 6 | **Training** |  | 45.75d | 2024-02-16 | 2024-04-19 |  | 3d |  |  | 256h |
| 54 | 6.1 | Develop training specifications for end users |  | 3d | 2024-02-16 | 2024-02-20 | 26 | 21.75d | 18.75d | Trainers | 24h |
| 55 | 6.2 | Develop training specifications for helpdesk support staff |  | 3d | 2024-02-16 | 2024-02-20 | 26 | 21.75d | 18.75d | Trainers | 24h |
| 56 | 6.3 | Identify training delivery methodology (computer based training, classroom, etc.) |  | 2d | 2024-02-16 | 2024-02-19 | 26 | 22.75d | 19.75d | Trainers | 16h |
| 57 | 6.4 | Develop training materials |  | 3w | 2024-03-18 | 2024-04-08 | 54, 34, 55, 56 | 3d | 0d | Trainers | 120h |
| 58 | 6.5 | Conduct training usability study |  | 4d | 2024-04-08 | 2024-04-12 | 57 | 3d | 0d | Trainers | 32h |
| 59 | 6.6 | Finalize training materials |  | 3d | 2024-04-12 | 2024-04-17 | 58 | 3d | 0d | Trainers | 24h |
| 60 | 6.7 | Develop training delivery mechanism |  | 2d | 2024-04-17 | 2024-04-19 | 59 | 3d | 0d | Trainers | 16h |
| 61 | 6.8 | Training materials complete | milestone | 0d | 2024-04-19 | 2024-04-19 | 60 | 3d |  |  |  |

| ID | WBS | Task | Type | Duration | Start | Finish | Predecessors | Total slack | Free slack | Resources | Work |
| --- | --- | --- | --- | --- | --- | --- | --- | --- | --- | --- | --- |
| 63 | 7 | **Documentation/Diagrams** |  | 30.5d | 2024-02-16 | 2024-03-29 |  | 18.25d |  |  | 336h |
| 64 | 7.1 | Develop Network specification Diagram |  | 1d | 2024-02-16 | 2024-02-16 | 26 | 27.75d | 9.5d | Technical Communicators | 8h |
| 65 | 7.2 | Develop Help system |  | 3w | 2024-03-01 | 2024-03-22 | 64, 32FS-7.5d | 18.25d | 0d | Technical Communicators | 120h |
| 66 | 7.3 | Review Help documentation |  | 3d | 2024-03-22 | 2024-03-27 | 65 | 18.25d | 0d | Technical Communicators | 24h |
| 67 | 7.4 | Incorporate Help documentation feedback |  | 2d | 2024-03-27 | 2024-03-29 | 66 | 18.25d | 0d | Technical Communicators | 16h |
| 68 | 7.5 | Develop user manuals specifications |  | 2d | 2024-02-16 | 2024-02-19 | 26 | 27.75d | 8.5d | Technical Communicators | 16h |
| 69 | 7.6 | Develop user manuals |  | 3w | 2024-03-01 | 2024-03-22 | 68, 32FS-7.5d | 19.25d | 0d | Technical Communicators | 120h |
| 70 | 7.7 | Review all user documentation |  | 2d | 2024-03-22 | 2024-03-26 | 69 | 19.25d | 0d | Technical Communicators | 16h |
| 71 | 7.8 | Incorporate user documentation feedback |  | 2d | 2024-03-26 | 2024-03-28 | 70 | 19.25d | 1d | Technical Communicators | 16h |
| 72 | 7.9 | Documentation complete | milestone | 0d | 2024-03-29 | 2024-03-29 | 71, 67 | 18.25d |  |  |  |
| 74 | 8 | **Pilot** |  | 70.25d | 2024-01-26 | 2024-05-03 |  | 0d |  |  | 64h |
| 75 | 8.1 | Identify test group |  | 1d | 2024-01-26 | 2024-01-29 | 17 | 61.25d | 0d | Project Manager | 8h |
| 76 | 8.2 | Develop network delivery mechanism |  | 1d | 2024-01-29 | 2024-01-30 | 75 | 61.25d |  |  |  |
| 77 | 8.3 | Install/deploy network |  | 1d | 2024-04-24 | 2024-04-25 | 51, 76, 72, 61 | 0d |  | Deployment Team | 8h |
| 78 | 8.4 | Obtain user feedback |  | 1w | 2024-04-25 | 2024-05-02 | 77 | 0d |  | Deployment Team | 40h |
| 79 | 8.5 | Evaluate testing information |  | 1d | 2024-05-02 | 2024-05-03 | 78 | 0d |  | Deployment Team | 8h |
| 80 | 8.6 | Pilot complete | milestone | 0d | 2024-05-03 | 2024-05-03 | 79 | 0d |  |  |  |
| 82 | 9 | **Deployment** |  | 5d | 2024-05-03 | 2024-05-10 |  | 0d |  |  | 40h |
| 83 | 9.1 | Determine final deployment strategy |  | 1d | 2024-05-03 | 2024-05-06 | 80 | 0d |  | Deployment Team | 8h |
| 84 | 9.2 | Develop deployment methodology |  | 1d | 2024-05-06 | 2024-05-07 | 83 | 0d |  | Deployment Team | 8h |
| 85 | 9.3 | Secure deployment resources |  | 1d | 2024-05-07 | 2024-05-08 | 84 | 0d |  | Deployment Team | 8h |
| 86 | 9.4 | Train support staff |  | 1d | 2024-05-08 | 2024-05-09 | 85 | 0d |  | Deployment Team | 8h |
| 87 | 9.5 | Deploy network |  | 1d | 2024-05-09 | 2024-05-10 | 86 | 0d |  | Deployment Team | 8h |
| 88 | 9.6 | Deployment complete | milestone | 0d | 2024-05-10 | 2024-05-10 | 87 | 0d |  |  |  |

| ID | WBS | Task | Type | Duration | Start | Finish | Predecessors | Total slack | Resources | Work |
| --- | --- | --- | --- | --- | --- | --- | --- | --- | --- | --- |
| 90 | 10 | **Post Implementation Review** |  | 3d | 2024-05-10 | 2024-05-15 |  | 0d |  | 24h |
| 91 | 10.1 | Document lessons learned (Lessons Log) |  | 1d | 2024-05-10 | 2024-05-13 | 88 | 0d | Project Manager | 8h |
| 92 | 10.2 | Distribute to team members |  | 1d | 2024-05-13 | 2024-05-14 | 91 | 0d | Project Manager | 8h |
| 93 | 10.3 | Create network maintenance team |  | 1d | 2024-05-14 | 2024-05-15 | 92 | 0d | Project Manager | 8h |
| 94 | 10.4 | Post implementation review complete | milestone | 0d | 2024-05-15 | 2024-05-15 | 93 | 0d |  |  |
| 95 | 11 | Network development template complete | milestone | 0d | 2024-05-15 | 2024-05-15 | 94 | 0d |  |  |
