# Network Upgrade Services Deployment

Schedule from MS Project, 2024-01-08 to 2024-05-06.
Willcox PMO

## Calendars

- Standard: Mon-Fri 08:00-12:00, 13:00-17:00; Sat-Sun off.

## Resources

| Resource |
| --- |
| Stakeholders |
| Project Manager |
| Systems Architect |
| Team Members |
| Network Administrator |
| Database Administrator |
| User Education/Training |
| Desktop Support |
| Server Administrator |
| IT Support Staff |
| Application Deployment |
| Test/QA |
| Project Managers |

## Schedule

| ID | WBS | Task | Type | Duration | Start | Finish | Predecessors | Total slack | Free slack | Resources | Work |
| --- | --- | --- | --- | --- | --- | --- | --- | --- | --- | --- | --- |
| 1 | 1 | **Network Upgrade Services Deployment** |  | 10d | 2024-01-08 | 2024-01-19 |  | 0d |  |  | 80h |
| 2 | 1.1 | **Visualization** |  | 10d | 2024-01-08 | 2024-01-19 |  | 0d |  |  | 80h |
| 3 | 1.1.1 | Summarize current team collaboration environment |  | 2d | 2024-01-08 | 2024-01-09 |  | 0d |  | Stakeholders | 16h |
| 4 | 1.1.2 | Identify team collaboration vision concerns (multinational, etc.) |  | 2d | 2024-01-10 | 2024-01-11 | 3 | 0d |  | Stakeholders | 16h |
| 5 | 1.1.3 | Determine project scope (early adopters, departmental deployment, etc.) |  | 3d | 2024-01-12 | 2024-01-16 | 4 | 0d |  | Stakeholders | 24h |
| 6 | 1.1.4 | Determine major milestones |  | 1d | 2024-01-17 | 2024-01-17 | 5 | 0d |  | Stakeholders | 8h |
| 7 | 1.1.5 | Secure executive sponsorship |  | 2d | 2024-01-18 | 2024-01-19 | 6 | 0d |  | Stakeholders | 16h |
| 8 | 1.1.6 | Visualization complete | milestone | 0d | 2024-01-19 | 2024-01-19 | 7 | 0d |  |  |  |
| 10 | 2 | **Planning** |  | 0.5d | 2024-01-22 | 2024-01-22 | 2 | 0d |  |  | 84h |
| 11 | 2.1 | **Assemble Project Teams/Define Roles** |  | 0.5d | 2024-01-22 | 2024-01-22 |  | 0d |  |  | 84h |
| 12 | 2.1.1 | Identify project manager |  | 4h | 2024-01-22 | 2024-01-22 |  | 0d |  | Stakeholders | 4h |
| 13 | 2.1.2 | Identify database administrator |  | 4h | 2024-01-22 | 2024-01-22 |  | 0d |  | Project Manager; Stakeholders | 8h |
| 14 | 2.1.3 | Identify network administrator |  | 4h | 2024-01-22 | 2024-01-22 |  | 0d |  | Project Manager; Stakeholders | 8h |
| 15 | 2.1.4 | Identify IT support staff |  | 4h | 2024-01-22 | 2024-01-22 |  | 0d |  | Project Manager; Stakeholders | 8h |
| 16 | 2.1.5 | Identify server administrator |  | 4h | 2024-01-22 | 2024-01-22 |  | 0d |  | Project Manager; Stakeholders | 8h |
| 17 | 2.1.6 | Identify systems architect |  | 4h | 2024-01-22 | 2024-01-22 |  | 0d |  | Project Manager; Stakeholders | 8h |
| 18 | 2.1.7 | Identify desktop support lead |  | 4h | 2024-01-22 | 2024-01-22 |  | 0d |  | Project Manager; Stakeholders | 8h |
| 19 | 2.1.8 | Identify application deployment team |  | 4h | 2024-01-22 | 2024-01-22 |  | 0d |  | Project Manager; Stakeholders | 8h |
| 20 | 2.1.9 | Identify team members |  | 4h | 2024-01-22 | 2024-01-22 |  | 0d |  | Project Manager; Stakeholders | 8h |
| 21 | 2.1.10 | Identify test/QA lead |  | 4h | 2024-01-22 | 2024-01-22 |  | 0d |  | Project Manager; Stakeholders | 8h |
| 22 | 2.1.11 | Identify user education/training lead |  | 4h | 2024-01-22 | 2024-01-22 |  | 0d |  | Project Manager; Stakeholders | 8h |
| 23 | 2.1.12 | Assemble project teams/define roles complete | milestone | 0d | 2024-01-22 | 2024-01-22 | 12, 13, 14, 15, 16, 17, 18, 19, 20, 21, 22 | 0d |  |  |  |
| 25 | 3 | **Plan Network Configuration** |  | 8d | 2024-01-22 | 2024-02-01 | 11 | 45.5d | 0d |  | 112h |
| 26 | 3.1 | Identify design objectives |  | 4d | 2024-01-22 | 2024-01-26 |  | 45.5d | 0d | Project Manager; Systems Architect | 64h |
| 27 | 3.2 | Complete implementation risk assessment |  | 2d | 2024-01-26 | 2024-01-30 | 26 | 45.5d | 0d | Project Manager | 16h |
| 28 | 3.3 | Determine network Services components to install to meet goals |  | 2d | 2024-01-30 | 2024-02-01 | 27 | 45.5d | 0d | Project Manager; Team Members | 32h |
| 29 | 3.4 | Plan network configuration complete | milestone | 0d | 2024-02-01 | 2024-02-01 | 28 | 45.5d |  |  |  |

| ID | WBS | Task | Type | Duration | Start | Finish | Predecessors | Total slack | Free slack | Resources | Work |
| --- | --- | --- | --- | --- | --- | --- | --- | --- | --- | --- | --- |
| 31 | 4 | **Perform Capacity Planning** |  | 2d | 2024-02-01 | 2024-02-05 | 25 | 55.5d | 0d |  | 48h |
| 32 | 4.1 | **Identify Roles of Users** |  | 1d | 2024-02-01 | 2024-02-02 |  | 55.5d | 0d |  | 32h |
| 33 | 4.1.1 | Identify readers |  | 1d | 2024-02-01 | 2024-02-02 |  | 55.5d |  | Team Members | 8h |
| 34 | 4.1.2 | Identify contributors |  | 1d | 2024-02-01 | 2024-02-02 |  | 55.5d |  | Team Members | 8h |
| 35 | 4.1.3 | Identify Web designers |  | 1d | 2024-02-01 | 2024-02-02 |  | 55.5d |  | Team Members | 8h |
| 36 | 4.1.4 | Identify custom roles |  | 1d | 2024-02-01 | 2024-02-02 |  | 55.5d |  | Team Members | 8h |
| 37 | 4.2 | Determine number of users in each role |  | 1d | 2024-02-02 | 2024-02-05 | 32 | 55.5d | 0d | Team Members | 8h |
| 38 | 4.3 | Determine usage patterns by role |  | 1d | 2024-02-02 | 2024-02-05 | 32 | 55.5d | 0d | Team Members | 8h |
| 40 | 5 | **Determine Required Server Capacity from Role Analysis** |  | 7d | 2024-02-05 | 2024-02-14 | 32, 37, 38 | 55.5d | 0d |  | 104h |
| 41 | 5.1 | Determine architecture for servers (e.g. single box or Web farm framework, clustering for scalability, etc.) |  | 3d | 2024-02-05 | 2024-02-08 |  | 55.5d | 0d | Systems Architect | 24h |
| 42 | 5.2 | Develop architectural diagram |  | 2d | 2024-02-08 | 2024-02-12 | 41 | 55.5d | 0d | Systems Architect | 16h |
| 43 | 5.3 | Size Web servers |  | 1d | 2024-02-12 | 2024-02-13 | 42 | 55.5d | 0d | Network Administrator; Systems Architect | 16h |
| 44 | 5.4 | Size database servers |  | 1d | 2024-02-12 | 2024-02-13 | 42 | 55.5d | 0d | Database Administrator; Systems Architect | 16h |
| 45 | 5.5 | Determine quantity of Web servers |  | 1d | 2024-02-13 | 2024-02-14 | 43 | 55.5d |  | Network Administrator; Systems Architect | 16h |
| 46 | 5.6 | Determine quantity of database servers |  | 1d | 2024-02-13 | 2024-02-14 | 44 | 55.5d |  | Database Administrator; Systems Architect | 16h |
| 47 | 5.7 | Perform capacity planning complete | milestone | 0d | 2024-02-05 | 2024-02-05 |  | 62.5d |  |  |  |
| 49 | 6 | **Define Training Strategy** |  | 22d | 2024-02-01 | 2024-03-04 | 25 | 45.5d | 0d |  | 176h |
| 50 | 6.1 | Determine users to be trained |  | 2d | 2024-02-01 | 2024-02-05 |  | 45.5d | 0d | User Education/Training | 16h |
| 51 | 6.2 | Develop training documentation |  | 10d | 2024-02-05 | 2024-02-19 | 50 | 45.5d | 0d | User Education/Training | 80h |
| 52 | 6.3 | Train pilot team |  | 10d | 2024-02-19 | 2024-03-04 | 51 | 45.5d | 0d | User Education/Training | 80h |
| 53 | 6.4 | Define training strategy complete | milestone | 0d | 2024-03-04 | 2024-03-04 | 52 | 45.5d |  |  |  |
| 55 | 7 | **Plan Upgrade** |  | 12d | 2024-02-01 | 2024-02-19 | 25 | 55.5d |  |  | 296h |
| 56 | 7.1 | **Identify Coexistence Strategies** |  | 4d | 2024-02-01 | 2024-02-07 |  | 55.5d | 8d |  | 48h |
| 57 | 7.1.1 | Identify interoperability issues with applications (Network technologies versions, Microsoft Office System program versions, suites, etc.) |  | 2d | 2024-02-01 | 2024-02-05 |  | 65.5d |  | Systems Architect | 16h |
| 58 | 7.1.2 | Identify interoperability issues with the organization's partners (Network CLI versions, Microsoft Office Legacy Systems, suites, etc.) |  | 2d | 2024-02-01 | 2024-02-05 |  | 55.5d | 0d | Systems Architect | 16h |
| 59 | 7.1.3 | Identify interoperability issues with third-party packages |  | 2d | 2024-02-05 | 2024-02-07 | 58 | 55.5d | 0d | Systems Architect | 16h |
| 60 | 7.1.4 | Identify coexistence strategies complete | milestone | 0d | 2024-02-07 | 2024-02-07 | 59 | 55.5d | 0d |  |  |

| ID | WBS | Task | Type | Duration | Start | Finish | Predecessors | Total slack | Free slack | Resources | Work |
| --- | --- | --- | --- | --- | --- | --- | --- | --- | --- | --- | --- |
| 61 | 7.2 | **Identify Migration Strategies (If Currently Using Network Team Services)** |  | 8d | 2024-02-07 | 2024-02-19 |  | 55.5d | 0d |  | 136h |
| 62 | 7.2.1 | Develop document migration strategy for Network Team Services |  | 3d | 2024-02-07 | 2024-02-12 | 60 | 55.5d | 0d | Systems Architect | 24h |
| 63 | 7.2.2 | Identify Network Team Services subwebs for proactive document migration (mass conversion) |  | 5d | 2024-02-12 | 2024-02-19 | 62 | 55.5d |  | Systems Architect; Team Members | 80h |
| 64 | 7.2.3 | "Identify Network Team Services subwebs for ""as-used"" migration (requires Network Team Services remains on separate servers)" |  | 1d | 2024-02-12 | 2024-02-13 | 62 | 59.5d |  | Systems Architect; Team Members | 16h |
| 65 | 7.2.4 | Identify Network Team Services subwebs not being migrated |  | 1d | 2024-02-12 | 2024-02-13 | 62 | 59.5d |  | Systems Architect; Team Members | 16h |
| 66 | 7.3 | Plan upgrade complete | milestone | 0d | 2024-02-19 | 2024-02-19 | 56, 61 | 55.5d |  |  |  |
| 68 | 7.4 | **Define Infrastructure** |  | 4.5d | 2024-02-01 | 2024-02-07 | 25 | 63d |  |  | 112h |
| 69 | 7.4.1 | **Evaluate and Upgrade Network** |  | 4.5d | 2024-02-01 | 2024-02-07 |  | 63d | 4.5d |  | 112h |
| 70 | 7.4.1.1 | **Identify Existing Network** |  | 1d | 2024-02-01 | 2024-02-02 |  | 64d | 1d |  | 48h |
| 71 | 7.4.1.1.1 | Diagram and document LAN connections |  | 1d | 2024-02-01 | 2024-02-02 |  | 64d |  | Database Administrator; Network Administrator | 16h |
| 72 | 7.4.1.1.2 | Diagram and document WAN connections |  | 1d | 2024-02-01 | 2024-02-02 |  | 64d |  | Database Administrator; Network Administrator | 16h |
| 73 | 7.4.1.1.3 | Diagram and document external user connections |  | 1d | 2024-02-01 | 2024-02-02 |  | 64d |  | Database Administrator; Network Administrator | 16h |
| 74 | 7.4.1.2 | **Handle Network Upgrades** |  | 2.5d | 2024-02-05 | 2024-02-07 | 70, 31 | 63d |  |  | 64h |
| 75 | 7.4.1.2.1 | Add additional bandwidth as required |  | 12h | 2024-02-05 | 2024-02-06 |  | 64d |  | Database Administrator; Network Administrator | 24h |
| 76 | 7.4.1.2.2 | Configure a VPN solution as needed |  | 20h | 2024-02-05 | 2024-02-07 |  | 63d |  | Database Administrator; Network Administrator | 40h |
| 78 | 8 | **Document Hardware** |  | 2d | 2024-02-05 | 2024-02-07 | 70, 31 | 63.5d |  |  | 64h |
| 79 | 8.1 | **Identify Server Environment** |  | 2d | 2024-02-05 | 2024-02-07 |  | 63.5d |  |  | 64h |
| 80 | 8.1.1 | **Identify Server Operating Systems** |  | 1d | 2024-02-05 | 2024-02-06 |  | 64.5d |  |  | 24h |
| 81 | 8.1.1.1 | Identify legacy Windows servers |  | 1d | 2024-02-05 | 2024-02-06 |  | 64.5d |  | Systems Architect | 8h |
| 82 | 8.1.1.2 | Identify Microsoft Windows Server 2022 servers |  | 1d | 2024-02-05 | 2024-02-06 |  | 64.5d |  | Systems Architect | 8h |
| 83 | 8.1.1.3 | Plan upgrade to Windows Server 2022 as required (you may want to use the Windows 2022 Server Deployment template to help) |  | 1d | 2024-02-05 | 2024-02-06 |  | 64.5d |  | Systems Architect | 8h |
| 84 | 8.1.2 | **Identify Server Hardware** |  | 2d | 2024-02-05 | 2024-02-07 |  | 63.5d |  |  | 40h |
| 85 | 8.1.2.1 | Identify Web servers for network Services |  | 1d | 2024-02-05 | 2024-02-06 |  | 63.5d | 0d | Network Administrator; Systems Architect | 16h |
| 86 | 8.1.2.2 | Identify database servers for network Services |  | 1d | 2024-02-05 | 2024-02-06 |  | 63.5d | 0d | Database Administrator; Systems Architect | 16h |
| 87 | 8.1.2.3 | Purchase additional servers as needed |  | 1d | 2024-02-06 | 2024-02-07 | 85, 86 | 63.5d |  | Systems Architect | 8h |

| ID | WBS | Task | Type | Duration | Start | Finish | Predecessors | Total slack | Free slack | Resources | Work |
| --- | --- | --- | --- | --- | --- | --- | --- | --- | --- | --- | --- |
| 89 | 9 | **Document Clients** |  | 8d | 2024-01-08 | 2024-01-17 |  | 78d |  |  | 232h |
| 90 | 9.1 | **Identify Operating Systems** |  | 1d | 2024-01-08 | 2024-01-08 |  | 85d |  |  | 32h |
| 91 | 9.1.1 | Identify users of Microsoft Windows 10/11 |  | 1d | 2024-01-08 | 2024-01-08 |  | 85d |  | Desktop Support | 8h |
| 92 | 9.1.2 | Identify users of Microsoft Windows 11, Microsoft Windows Office 2021, Microsoft Windows 10 |  | 1d | 2024-01-08 | 2024-01-08 |  | 85d |  | Desktop Support | 8h |
| 93 | 9.1.3 | Identify users of non-Windows clients |  | 1d | 2024-01-08 | 2024-01-08 |  | 85d |  | Desktop Support | 8h |
| 94 | 9.1.4 | Identify users of non-PC clients |  | 1d | 2024-01-08 | 2024-01-08 |  | 85d |  | Desktop Support | 8h |
| 95 | 9.2 | **Identify Browsers in Use** |  | 8d | 2024-01-08 | 2024-01-17 |  | 78d |  |  | 112h |
| 96 | 9.2.1 | Identify users of Chrome |  | 1d | 2024-01-08 | 2024-01-08 |  | 80d | 2d | Desktop Support | 8h |
| 97 | 9.2.2 | Identify users of Edge |  | 1d | 2024-01-08 | 2024-01-08 |  | 80d | 2d | Desktop Support | 8h |
| 98 | 9.2.3 | Identify users of Firefox/Other |  | 1d | 2024-01-08 | 2024-01-08 |  | 80d | 2d | Desktop Support | 8h |
| 99 | 9.2.4 | Document work-arounds and procedures for users of older versions of Web browsers |  | 3d | 2024-01-08 | 2024-01-10 |  | 78d | 0d | Systems Architect; Team Members | 48h |
| 100 | 9.2.5 | Determine browser upgrade strategy as needed |  | 5d | 2024-01-11 | 2024-01-17 | 96, 97, 98, 99 | 78d |  | Desktop Support | 40h |
| 101 | 9.3 | **Identify Microsoft Office System Versions in Use** |  | 6d | 2024-01-08 | 2024-01-15 |  | 80d |  |  | 88h |
| 102 | 9.3.1 | Identify users without Microsoft Office |  | 1d | 2024-01-08 | 2024-01-08 |  | 80d | 0d | Desktop Support | 8h |
| 103 | 9.3.2 | Identify users of Microsoft Office 2019 |  | 1d | 2024-01-08 | 2024-01-08 |  | 80d | 0d | Desktop Support | 8h |
| 104 | 9.3.3 | Identify users of Microsoft Windows 11 |  | 1d | 2024-01-08 | 2024-01-08 |  | 80d | 0d | Desktop Support | 8h |
| 105 | 9.3.4 | Identify users of Microsoft Office 2021 |  | 1d | 2024-01-08 | 2024-01-08 |  | 80d | 0d | Desktop Support | 8h |
| 106 | 9.3.5 | Document work-arounds and procedures for users of older versions of Microsoft Office System |  | 1d | 2024-01-08 | 2024-01-08 |  | 80d | 0d | Systems Architect; Team Members | 16h |
| 107 | 9.3.6 | Determine Microsoft Office upgrade strategy as needed (if performing a Microsoft Office System upgrade refer to the Microsoft Office System Deployment template for more information) |  | 5d | 2024-01-09 | 2024-01-15 | 102, 103, 104, 105, 106 | 80d |  | Desktop Support | 40h |
| 109 | 10 | **Evaluate Messaging Infrastructure** |  | 3d | 2024-02-14 | 2024-02-19 | 40 | 55.5d |  |  | 24h |
| 110 | 10.1 | Determine SMTP capability |  | 1d | 2024-02-14 | 2024-02-15 |  | 55.5d | 0d | Network Administrator | 8h |
| 111 | 10.2 | Determine ability to handle increased volume from network Services notifications |  | 1d | 2024-02-15 | 2024-02-16 | 110 | 55.5d | 0d | Network Administrator | 8h |
| 112 | 10.3 | "Determine message ""from account"" and configure mailbox appropriately" |  | 1d | 2024-02-16 | 2024-02-19 | 111 | 55.5d |  | Network Administrator | 8h |
| 113 | 10.4 | "Plan integration with Application Gateway ""v2.0"" as desired (see Application Gateway ""v2.0"" Deployment template for more information)" | milestone | 0d | 2024-02-14 | 2024-02-14 |  | 58.5d | 0d | Systems Architect |  |
| 114 | 10.5 | Define infrastructure complete | milestone | 0d | 2024-02-14 | 2024-02-14 | 69, 113 | 58.5d |  |  |  |

| ID | WBS | Task | Type | Duration | Start | Finish | Predecessors | Total slack | Free slack | Resources | Work |
| --- | --- | --- | --- | --- | --- | --- | --- | --- | --- | --- | --- |
| 116 | 11 | **Define Security** |  | 5d | 2024-01-08 | 2024-01-12 |  | 81d |  |  | 168h |
| 117 | 11.1 | Create network service accounts |  | 1d | 2024-01-08 | 2024-01-08 |  | 85d | 0d | Network Administrator | 8h |
| 118 | 11.2 | Define network Services roles |  | 1d | 2024-01-08 | 2024-01-08 |  | 85d | 0d | Systems Architect | 8h |
| 119 | 11.3 | Evaluate the Active Directory account configuration tool for management of users and permissions |  | 1d | 2024-01-08 | 2024-01-08 |  | 85d | 0d | Network Administrator | 8h |
| 120 | 11.4 | Define security complete | milestone | 0d | 2024-01-08 | 2024-01-08 | 117, 118, 119 | 85d |  |  |  |
| 121 | 11.5 | **Identify Localization Considerations** |  | 5d | 2024-01-08 | 2024-01-12 |  | 81d | 35.5d |  | 144h |
| 122 | 11.5.1 | Identify international usage scenarios |  | 3d | 2024-01-08 | 2024-01-10 |  | 83d | 2d | Project Manager; Team Members | 48h |
| 123 | 11.5.2 | Identify plans for providing localized content |  | 5d | 2024-01-08 | 2024-01-12 |  | 81d | 0d | Project Manager; Team Members | 80h |
| 124 | 11.5.3 | Identify language templates to use |  | 2d | 2024-01-08 | 2024-01-09 |  | 84d | 3d | Server Administrator | 16h |
| 125 | 11.5.4 | Identify localization considerations complete | milestone | 0d | 2024-01-12 | 2024-01-12 | 122, 123, 124 | 81d |  |  |  |
| 127 | 12 | **Plan Maintenance Considerations** |  | 40.5d | 2024-01-08 | 2024-03-04 |  | 45.5d |  |  | 112h |
| 128 | 12.1 | **Administrative Tasks** |  | 3d | 2024-01-08 | 2024-01-10 |  | 83d | 2d |  | 48h |
| 129 | 12.1.1 | Determine administrative support strategy |  | 1d | 2024-01-08 | 2024-01-08 |  | 83d | 0d | Network Administrator; IT Support Staff | 16h |
| 130 | 12.1.2 | Identify and train a systems administrator |  | 1d | 2024-01-09 | 2024-01-09 | 129 | 83d | 0d | Network Administrator; IT Support Staff | 16h |
| 131 | 12.1.3 | Define routine administrative tasks |  | 1d | 2024-01-10 | 2024-01-10 | 130 | 83d |  | Network Administrator; IT Support Staff | 16h |
| 132 | 12.2 | **Backup** |  | 3d | 2024-01-08 | 2024-01-10 |  | 81d | 0d |  | 32h |
| 133 | 12.2.1 | Determine backup frequency |  | 1d | 2024-01-08 | 2024-01-08 |  | 81d | 0d | Database Administrator; Network Administrator | 16h |
| 134 | 12.2.2 | Identify backup hardware |  | 1d | 2024-01-09 | 2024-01-09 | 133 | 81d | 0d | Network Administrator | 8h |
| 135 | 12.2.3 | Document backup procedures |  | 1d | 2024-01-10 | 2024-01-10 | 134 | 81d |  | Network Administrator | 8h |
| 136 | 12.3 | **Restore** |  | 2d | 2024-01-11 | 2024-01-12 | 132 | 81d | 0d |  | 32h |
| 137 | 12.3.1 | Document restoration/disaster recovery process |  | 1d | 2024-01-11 | 2024-01-11 |  | 81d | 0d | Database Administrator; Network Administrator | 16h |
| 138 | 12.3.2 | Test restore of backups |  | 1d | 2024-01-12 | 2024-01-12 | 137 | 81d |  | Database Administrator; Network Administrator | 16h |
| 139 | 12.4 | Plan maintenance considerations complete | milestone | 0d | 2024-01-12 | 2024-01-12 | 128, 132, 136 | 81d |  |  |  |
| 140 | 12.5 | Planning complete | milestone | 0d | 2024-03-04 | 2024-03-04 | 11, 25, 31, 49, 121 | 45.5d |  |  |  |

| ID | WBS | Task | Duration | Start | Finish | Predecessors | Total slack | Free slack | Resources | Work |
| --- | --- | --- | --- | --- | --- | --- | --- | --- | --- | --- |
| 142 | 13 | **Deployment** | 45.5d | 2024-01-22 | 2024-03-25 | 10 | 0d |  |  | 680h |
| 143 | 13.1 | **Pilot Deployment** | 25.5d | 2024-01-22 | 2024-02-26 |  | 0d |  |  | 444h |
| 144 | 13.1.1 | **Deploy Servers** | 25.5d | 2024-01-22 | 2024-02-26 |  | 0d |  |  | 324h |
| 145 | 13.1.1.1 | Complete hardware setup | 5d | 2024-01-22 | 2024-01-29 |  | 0d |  | Server Administrator | 40h |
| 146 | 13.1.1.2 | **Complete network Installation** | 20.5d | 2024-01-29 | 2024-02-26 | 145 | 0d |  |  | 284h |
| 147 | 13.1.1.2.1 | Install Windows Server 2022 | 2d | 2024-01-29 | 2024-01-31 |  | 0d |  | Server Administrator | 16h |
| 148 | 13.1.1.2.2 | Install SQL Servers | 2d | 2024-01-31 | 2024-02-02 | 147 | 0d |  | Database Administrator | 16h |
| 149 | 13.1.1.2.3 | Install Web server role in Windows Server 2022 | 1d | 2024-02-02 | 2024-02-05 | 148 | 0d |  | Server Administrator | 8h |
| 150 | 13.1.1.2.4 | Install network Services | 1d | 2024-02-05 | 2024-02-06 | 149 | 0d |  | Server Administrator | 8h |
| 151 | 13.1.1.2.5 | **Complete network Configuration** | 14.5d | 2024-02-06 | 2024-02-26 | 150 | 0d |  |  | 236h |
| 152 | 13.1.1.2.5.1 | Create quota templates | 2d | 2024-02-06 | 2024-02-08 |  | 12.5d |  | Server Administrator | 16h |
| 153 | 13.1.1.2.5.2 | **Configure Sites and Site Collections** | 6.5d | 2024-02-06 | 2024-02-14 |  | 0d |  |  | 52h |
| 154 | 13.1.1.2.5.2.1 | Create virtual directories as needed in Internet Information Server (IIS) | 4h | 2024-02-06 | 2024-02-06 |  | 0d |  | Server Administrator | 4h |
| 155 | 13.1.1.2.5.2.2 | Create content databases | 1d | 2024-02-07 | 2024-02-07 | 154 | 0d |  | Database Administrator | 8h |
| 156 | 13.1.1.2.5.2.3 | Extend virtual directories | 4h | 2024-02-08 | 2024-02-08 | 155 | 0d |  | Server Administrator | 4h |
| 157 | 13.1.1.2.5.2.4 | Configure self-service site creation | 4h | 2024-02-08 | 2024-02-08 | 156 | 0d |  | Server Administrator | 4h |
| 158 | 13.1.1.2.5.2.5 | Configure site collection to use confirmation and auto-deletion | 4h | 2024-02-09 | 2024-02-09 | 157 | 7d | 0d | Server Administrator | 4h |
| 159 | 13.1.1.2.5.2.6 | Configure user rights for virtual directories | 2d | 2024-02-09 | 2024-02-13 | 158 | 7d | 0d | Server Administrator | 16h |
| 160 | 13.1.1.2.5.2.7 | Configure e-mail settings | 4h | 2024-02-13 | 2024-02-13 | 159 | 7d | 0d | Server Administrator | 4h |
| 161 | 13.1.1.2.5.2.8 | Create top-level Web sites | 4h | 2024-02-14 | 2024-02-14 | 160 | 7d | 0d | Server Administrator | 4h |
| 162 | 13.1.1.2.5.2.9 | Select pertinent quota template | 4h | 2024-02-14 | 2024-02-14 | 161 | 7d |  | Server Administrator | 4h |
| 163 | 13.1.1.2.5.3 | **Customize Site Template** | 12d | 2024-02-09 | 2024-02-26 | 157 | 0d |  |  | 96h |
| 164 | 13.1.1.2.5.3.1 | Implement custom lists | 2d | 2024-02-09 | 2024-02-12 |  | 0d |  | Team Members | 16h |
| 165 | 13.1.1.2.5.3.2 | Implement custom site layout template(s) with Microsoft Office FrontPage 2022 | 5d | 2024-02-13 | 2024-02-19 | 164 | 0d |  | Team Members | 40h |
| 166 | 13.1.1.2.5.3.3 | Define document folders | 5d | 2024-02-20 | 2024-02-26 | 165 | 0d |  | Team Members | 40h |
| 167 | 13.1.1.2.5.4 | Configure full-text indexing | 1d | 2024-02-15 | 2024-02-15 | 153 | 7d |  | Server Administrator | 8h |
| 168 | 13.1.1.2.5.5 | Setup blocked file types | 1d | 2024-02-15 | 2024-02-15 | 153 | 7d |  | Server Administrator | 8h |
| 169 | 13.1.1.2.5.6 | Configure usage analysis processing | 1d | 2024-02-15 | 2024-02-15 | 153 | 7d |  | Server Administrator | 8h |
| 170 | 13.1.1.2.5.7 | Configure DSP settings | 1d | 2024-02-15 | 2024-02-15 | 153 | 7d |  | Server Administrator | 8h |
| 171 | 13.1.1.2.5.8 | "Configure Application Gateway ""v2.0"" integration as desired (See Application Gateway ""v2.0"" Deployment template for more information)" | 5d | 2024-02-06 | 2024-02-13 |  | 9.5d |  | Server Administrator | 40h |

| ID | WBS | Task | Type | Duration | Start | Finish | Predecessors | Total slack | Free slack | Resources | Work |
| --- | --- | --- | --- | --- | --- | --- | --- | --- | --- | --- | --- |
| 172 | 13.1.2 | **Configure network Services Clients** |  | 10d | 2024-01-22 | 2024-02-05 |  | 15.5d |  |  | 120h |
| 173 | 13.1.2.1 | Upgrade client operating systems as needed |  | 5d | 2024-01-22 | 2024-01-29 |  | 15.5d | 0d | Application Deployment | 40h |
| 174 | 13.1.2.2 | Upgrade client browsers as needed |  | 5d | 2024-01-29 | 2024-02-05 | 173 | 15.5d |  | Application Deployment | 40h |
| 175 | 13.1.2.3 | Upgrade client Microsoft Office System versions as desired |  | 5d | 2024-01-29 | 2024-02-05 | 173 | 15.5d |  | Application Deployment | 40h |
| 177 | 13.2 | **Perform Migration from Network Team Services** |  | 7.5d | 2024-01-22 | 2024-01-31 |  | 68d |  |  | 76h |
| 178 | 13.2.1 | **Select a Migration Method** |  | 1d | 2024-01-22 | 2024-01-23 |  | 68d | 0d |  | 24h |
| 179 | 13.2.1.1 | Select full backup and restore approach |  | 1d | 2024-01-22 | 2024-01-23 |  | 68d |  | Systems Architect | 8h |
| 180 | 13.2.1.2 | Select migration using the site migration tool (simigrate.exe) with two live servers |  | 1d | 2024-01-22 | 2024-01-23 |  | 68d |  | Systems Architect | 8h |
| 181 | 13.2.1.3 | Consider in-place upgrade of Network Team Services if other options are not acceptable |  | 1d | 2024-01-22 | 2024-01-23 |  | 68d |  | Systems Architect | 8h |
| 182 | 13.2.2 | Create a blank top-level Web site at the destination with no template applied |  | 4h | 2024-01-23 | 2024-01-23 | 178 | 68d | 0d | Server Administrator | 4h |
| 183 | 13.2.3 | Ensure settings are correct on the destination site |  | 4h | 2024-01-24 | 2024-01-24 | 182 | 68d | 0d | Server Administrator | 4h |
| 184 | 13.2.4 | Determine whether or not to preserve security settings |  | 4h | 2024-01-24 | 2024-01-24 | 183 | 68d | 0d | Systems Architect | 4h |
| 185 | 13.2.5 | Obtain administrative privileges on source and destination sites |  | 1d | 2024-01-25 | 2024-01-25 | 184 | 68d | 0d | Server Administrator | 8h |
| 186 | 13.2.6 | Execute the migration |  | 2d | 2024-01-26 | 2024-01-29 | 185 | 68d | 0d | Server Administrator | 16h |
| 187 | 13.2.7 | Compare migrated site to the original (not possible with in-place upgrade) |  | 2d | 2024-01-30 | 2024-01-31 | 186 | 68d |  | Team Members | 16h |
| 188 | 13.3 | **Test Pilot Environment** |  | 20d | 2024-02-27 | 2024-03-25 | 143 | 0d |  |  | 160h |
| 189 | 13.3.1 | Conduct desktop test scenarios |  | 5d | 2024-02-27 | 2024-03-04 |  | 0d |  | Test/QA | 40h |
| 190 | 13.3.2 | Conduct server test scenarios |  | 5d | 2024-03-05 | 2024-03-11 | 189 | 0d |  | Test/QA | 40h |
| 191 | 13.3.3 | Conduct third-party application test scenarios |  | 5d | 2024-03-12 | 2024-03-18 | 190 | 0d |  | Test/QA | 40h |
| 192 | 13.3.4 | Conduct custom application test scenarios |  | 5d | 2024-03-19 | 2024-03-25 | 191 | 0d |  | Test/QA | 40h |
| 193 | 13.4 | Pilot deployment complete | milestone | 0d | 2024-03-25 | 2024-03-25 | 143, 188 | 0d |  |  |  |
| 195 | 14 | **Production Deployment** |  | 30d | 2024-03-26 | 2024-05-06 | 193 | 0d |  |  | 938.4h |
| 196 | 14.1 | **Deploy Servers** |  | 25.5d | 2024-03-26 | 2024-04-30 |  | 4.5d |  |  | 324h |
| 197 | 14.1.1 | Complete hardware setup |  | 5d | 2024-03-26 | 2024-04-01 |  | 4.5d | 0d | Server Administrator | 40h |

| ID | WBS | Task | Duration | Start | Finish | Predecessors | Total slack | Free slack | Resources | Work |
| --- | --- | --- | --- | --- | --- | --- | --- | --- | --- | --- |
| 198 | 14.1.2 | **Complete network Installation** | 20.5d | 2024-04-02 | 2024-04-30 | 197 | 4.5d |  |  | 284h |
| 199 | 14.1.2.1 | Install Windows Server 2022 | 2d | 2024-04-02 | 2024-04-03 |  | 4.5d | 0d | Server Administrator | 16h |
| 200 | 14.1.2.2 | Install SQL Servers | 2d | 2024-04-04 | 2024-04-05 | 199 | 4.5d | 0d | Database Administrator | 16h |
| 201 | 14.1.2.3 | Install Web server role in Windows Server 2022 | 1d | 2024-04-08 | 2024-04-08 | 200 | 4.5d | 0d | Server Administrator | 8h |
| 202 | 14.1.2.4 | Install network Services | 1d | 2024-04-09 | 2024-04-09 | 201 | 4.5d | 0d | Server Administrator | 8h |
| 203 | 14.1.2.5 | **Complete network Configuration** | 14.5d | 2024-04-10 | 2024-04-30 | 202 | 4.5d |  |  | 236h |
| 204 | 14.1.2.5.1 | Create quota templates | 2d | 2024-04-10 | 2024-04-11 |  | 17d |  | Server Administrator | 16h |
| 205 | 14.1.2.5.2 | **Configure Sites and Site Collections** | 6.5d | 2024-04-10 | 2024-04-18 |  | 4.5d | 0d |  | 52h |
| 206 | 14.1.2.5.2.1 | Create virtual directories as needed in IIS | 4h | 2024-04-10 | 2024-04-10 |  | 4.5d | 0d | Server Administrator | 4h |
| 207 | 14.1.2.5.2.2 | Create content databases | 1d | 2024-04-10 | 2024-04-11 | 206 | 4.5d | 0d | Database Administrator | 8h |
| 208 | 14.1.2.5.2.3 | Extend virtual directories | 4h | 2024-04-11 | 2024-04-11 | 207 | 4.5d | 0d | Server Administrator | 4h |
| 209 | 14.1.2.5.2.4 | Configure self service site creation | 4h | 2024-04-12 | 2024-04-12 | 208 | 4.5d | 0d | Server Administrator | 4h |
| 210 | 14.1.2.5.2.5 | Configure site collection to use confirmation and auto-deletion | 4h | 2024-04-12 | 2024-04-12 | 209 | 11.5d | 0d | Server Administrator | 4h |
| 211 | 14.1.2.5.2.6 | Configure user rights for virtual directories | 2d | 2024-04-15 | 2024-04-16 | 210 | 11.5d | 0d | Server Administrator | 16h |
| 212 | 14.1.2.5.2.7 | Configure e-mail settings | 4h | 2024-04-17 | 2024-04-17 | 211 | 11.5d | 0d | Server Administrator | 4h |
| 213 | 14.1.2.5.2.8 | Create top-level Web sites | 4h | 2024-04-17 | 2024-04-17 | 212 | 11.5d | 0d | Server Administrator | 4h |
| 214 | 14.1.2.5.2.9 | Select pertinent quota template | 4h | 2024-04-18 | 2024-04-18 | 213 | 11.5d |  | Server Administrator | 4h |
| 215 | 14.1.2.5.3 | **Customize Site Template** | 12d | 2024-04-12 | 2024-04-30 | 209 | 4.5d |  |  | 96h |
| 216 | 14.1.2.5.3.1 | Implement custom lists | 2d | 2024-04-12 | 2024-04-16 |  | 4.5d | 0d | Team Members | 16h |
| 217 | 14.1.2.5.3.2 | Implement custom site layout templates | 5d | 2024-04-16 | 2024-04-23 | 216 | 4.5d | 0d | Team Members | 40h |
| 218 | 14.1.2.5.3.3 | Define document folders | 5d | 2024-04-23 | 2024-04-30 | 217 | 4.5d |  | Team Members | 40h |
| 219 | 14.1.2.5.4 | Configure full-text indexing | 1d | 2024-04-18 | 2024-04-19 | 205 | 11.5d |  | Server Administrator | 8h |
| 220 | 14.1.2.5.5 | Setup blocked file types | 1d | 2024-04-18 | 2024-04-19 | 205 | 11.5d |  | Server Administrator | 8h |
| 221 | 14.1.2.5.6 | Configure usage analysis processing | 1d | 2024-04-18 | 2024-04-19 | 205 | 11.5d |  | Server Administrator | 8h |
| 222 | 14.1.2.5.7 | Configure DSP settings | 1d | 2024-04-18 | 2024-04-19 | 205 | 11.5d |  | Server Administrator | 8h |
| 223 | 14.1.2.5.8 | "Configure Application Gateway ""v2.0"" integration as desired (See Application Gateway ""v2.0"" Deployment template for more information)" | 5d | 2024-04-10 | 2024-04-16 |  | 14d |  | Server Administrator | 40h |

| ID | WBS | Task | Type | Duration | Start | Finish | Predecessors | Total slack | Free slack | Resources | Work |
| --- | --- | --- | --- | --- | --- | --- | --- | --- | --- | --- | --- |
| 225 | 14.2 | **Configure network Services Clients** |  | 10d | 2024-03-26 | 2024-04-08 |  | 20d |  |  | 120h |
| 226 | 14.2.1 | Upgrade client operating systems as needed |  | 5d | 2024-03-26 | 2024-04-01 |  | 20d | 0d | Application Deployment | 40h |
| 227 | 14.2.2 | Upgrade client browsers as needed |  | 5d | 2024-04-02 | 2024-04-08 | 226 | 20d |  | Application Deployment | 40h |
| 228 | 14.2.3 | Upgrade client Microsoft Office System versions as desired |  | 5d | 2024-04-02 | 2024-04-08 | 226 | 20d |  | Application Deployment | 40h |
| 229 | 14.3 | **Perform Migration from Network Team Services** |  | 7.5d | 2024-03-26 | 2024-04-04 |  | 22.5d |  |  | 76h |
| 230 | 14.3.1 | **Select a Migration Method** |  | 1d | 2024-03-26 | 2024-03-26 |  | 22.5d | 0d |  | 24h |
| 231 | 14.3.1.1 | Select full backup and restore approach |  | 1d | 2024-03-26 | 2024-03-26 |  | 22.5d |  | Systems Architect | 8h |
| 232 | 14.3.1.2 | Select migration using the site migration tool (simigrate.exe) with two live servers |  | 1d | 2024-03-26 | 2024-03-26 |  | 22.5d |  | Systems Architect | 8h |
| 233 | 14.3.1.3 | Consider in-place upgrade of Network Team Services if other options are not acceptable |  | 1d | 2024-03-26 | 2024-03-26 |  | 22.5d |  | Systems Architect | 8h |
| 234 | 14.3.2 | Create a blank top-level Web site at the destination with no template applied |  | 4h | 2024-03-27 | 2024-03-27 | 230 | 22.5d | 0d | Server Administrator | 4h |
| 235 | 14.3.3 | Ensure settings are correct on the destination site |  | 4h | 2024-03-27 | 2024-03-27 | 234 | 22.5d | 0d | Server Administrator | 4h |
| 236 | 14.3.4 | Determine whether or not to preserve security settings |  | 4h | 2024-03-28 | 2024-03-28 | 235 | 22.5d | 0d | Systems Architect | 4h |
| 237 | 14.3.5 | Obtain administrative privileges on source and destination sites |  | 1d | 2024-03-28 | 2024-03-29 | 236 | 22.5d | 0d | Server Administrator | 8h |
| 238 | 14.3.6 | Execute the migration |  | 2d | 2024-03-29 | 2024-04-02 | 237 | 22.5d | 0d | Server Administrator | 16h |
| 239 | 14.3.7 | Compare migrated site to the original (not possible with in-place upgrade) |  | 2d | 2024-04-02 | 2024-04-04 | 238 | 22.5d |  | Team Members | 16h |
| 240 | 14.4 | **Test Production Environment** |  | 20d | 2024-03-26 | 2024-04-22 |  | 10d | 0d |  | 160h |
| 241 | 14.4.1 | Conduct desktop test scenarios |  | 5d | 2024-03-26 | 2024-04-01 |  | 10d | 0d | Test/QA | 40h |
| 242 | 14.4.2 | Conduct server test scenarios |  | 5d | 2024-04-02 | 2024-04-08 | 241 | 10d | 0d | Test/QA | 40h |
| 243 | 14.4.3 | Conduct third-party application test scenarios |  | 5d | 2024-04-09 | 2024-04-15 | 242 | 10d | 0d | Test/QA | 40h |
| 244 | 14.4.4 | Conduct custom application test scenarios |  | 5d | 2024-04-16 | 2024-04-22 | 243 | 10d |  | Test/QA | 40h |
| 245 | 14.5 | Production Deployment complete | milestone | 0d | 2024-04-22 | 2024-04-22 | 240 | 10d |  |  |  |
| 247 | 14.6 | **Post-deployment** |  | 30d | 2024-03-26 | 2024-05-06 |  | 0d |  |  | 258.4h |
| 248 | 14.6.1 | **Implement and Test Backup** |  | 1.25d | 2024-03-26 | 2024-03-27 |  | 28.75d |  |  | 24h |
| 249 | 14.6.1.1 | Implement backup strategy for network Services |  | 4h | 2024-03-26 | 2024-03-26 |  | 28.75d | 0d | Database Administrator; Server Administrator | 8h |
| 250 | 14.6.1.2 | Test network Services backup strategy |  | 4h | 2024-03-26 | 2024-03-26 | 249 | 28.75d | 0d | Database Administrator; Server Administrator | 8h |
| 251 | 14.6.1.3 | Implement and test disaster planning and recovery strategy |  | 2h | 2024-03-27 | 2024-03-27 | 250 | 28.75d | 0d | Database Administrator; Network Administrator; Server Administrator; Systems Architect | 8h |
| 252 | 14.6.1.4 | Implement and test backup complete | milestone | 0d | 2024-03-27 | 2024-03-27 | 251 | 28.75d |  |  |  |

| ID | WBS | Task | Type | Duration | Start | Finish | Predecessors | Total slack | Free slack | Resources | Work |
| --- | --- | --- | --- | --- | --- | --- | --- | --- | --- | --- | --- |
| 253 | 14.6.2 | **Implement Performance Tuning and Monitoring** |  | 30d | 2024-03-26 | 2024-05-06 |  | 0d |  |  | 115.2h |
| 254 | 14.6.2.1 | Observe performance parameters using performance monitor |  | 30d | 2024-03-26 | 2024-05-06 |  | 0d |  | Database Administrator [6%]; Server Administrator [6%] | 28.8h |
| 255 | 14.6.2.2 | Compare performance to plan |  | 30d | 2024-03-26 | 2024-05-06 |  | 0d |  | Database Administrator [6%]; Server Administrator [6%] | 28.8h |
| 256 | 14.6.2.3 | Tweak settings as needed |  | 30d | 2024-03-26 | 2024-05-06 |  | 0d |  | Database Administrator [6%]; Server Administrator [6%] | 28.8h |
| 257 | 14.6.2.4 | Re-forecast demand and plan appropriately |  | 30d | 2024-03-26 | 2024-05-06 |  | 0d |  | Database Administrator [6%]; Server Administrator [6%] | 28.8h |
| 258 | 14.6.2.5 | Implement performance tuning and monitoring complete | milestone | 0d | 2024-05-06 | 2024-05-06 | 254, 255, 256, 257 | 0d |  |  |  |
| 260 | 14.6.3 | **Set Up System Maintenance** |  | 30d | 2024-03-26 | 2024-05-06 |  | 0d |  |  | 23.2h |
| 261 | 14.6.3.1 | Create SQL Server maintenance plans |  | 4h | 2024-03-26 | 2024-03-26 |  | 29.5d |  | Database Administrator | 4h |
| 262 | 14.6.3.2 | Administer user accounts |  | 30d | 2024-03-26 | 2024-05-06 |  | 0d |  | Database Administrator [4%] | 9.6h |
| 263 | 14.6.3.3 | Monitor log and data files |  | 30d | 2024-03-26 | 2024-05-06 |  | 0d |  | Database Administrator [4%] | 9.6h |
| 264 | 14.6.3.4 | Set up system maintenance complete | milestone | 0d | 2024-05-06 | 2024-05-06 | 261, 262, 263 | 0d |  |  |  |
| 265 | 14.6.4 | Obtain user feedback |  | 2d | 2024-03-26 | 2024-03-27 |  | 21d | 0d | Team Members; Project Managers | 32h |
| 266 | 14.6.5 | Evaluate lessons learned (Create Lessons Log) |  | 3d | 2024-03-28 | 2024-04-01 | 265 | 21d | 0d | Team Members | 24h |
| 267 | 14.6.6 | Modify items as necessary |  | 3d | 2024-04-02 | 2024-04-04 | 266 | 21d | 0d | Team Members | 24h |
| 268 | 14.6.7 | Establish on-going network Services users team |  | 1d | 2024-04-05 | 2024-04-05 | 267 | 21d |  | Team Members; Project Managers | 16h |
| 269 | 14.6.8 | Post-deployment complete | milestone | 0d | 2024-05-06 | 2024-05-06 | 248, 253, 260, 268 | 0d |  |  |  |
| 270 | 14.7 | Microsoft network Services deployment complete | milestone | 0d | 2024-05-06 | 2024-05-06 | 247 | 0d |  |  |  |
