# Network Upgrade

Schedule from MS Project, 2023-01-03 to 2023-02-07, A marks actual dates.

## Calendars

- Standard: Mon-Fri 08:00-12:00, 13:00-17:00; Sat-Sun off.

## Schedule

| ID | WBS | Task | Type | Duration | Start | Finish | Predecessors | Complete | Remaining | Total slack | Constraint |
| --- | --- | --- | --- | --- | --- | --- | --- | --- | --- | --- | --- |
| 1 | 1 | **Establish New Office Network** |  | 26d? | 2023-01-03 A | 2023-02-07 |  | 29% | 18.57d? |  |  |
| 2 | 1.1 | **Project Management** |  | 6d? | 2023-01-03 A | 2023-01-10 |  | 29% | 4.29d? |  |  |
| 3 | 1.1.1 | Establish / Confirm vision |  | 1d? | 2023-01-05 A | 2023-01-05 A |  | 100% |  |  |  |
| 4 | 1.1.2 | Establish / Confirm scope |  | 6d? | 2023-01-03 A | 2023-01-10 | 3 | 17% | 5d? | 20d |  |
| 5 | 1.1.3 | This Project Is Finalized | milestone | 0d | 2023-01-10 A | 2023-01-10 A | 4 | 100% |  |  |  |
| 6 | 2 | **Collate Data. Gain Information On Existing LAN Performance** |  | 6d? | 2023-01-09 A | 2023-01-16 |  | 25% | 4.5d? |  |  |
| 7 | 2.1 | **Study The Network Performance (current state)** |  | 3d? | 2023-01-09 A | 2023-01-11 | 5 | 25% | 2.25d? |  |  |
| 8 | 2.1.1 | Establish and Confirm Findings |  | 1d? | 2023-01-09 A | 2023-01-09 A |  | 100% |  |  |  |
| 9 | 2.1.2 | Establish and Confirm Upgrade Process |  | 5d? | 2023-01-09 A | 2023-01-13 | 8 | 20% | 4d? | 0d |  |
| 10 | 2.1.3 | Review Plans With Client | milestone | 0d | 2023-01-09 | 2023-01-09 |  |  |  | 22d |  |
| 11 | 2.1.4 | Prioritize Tasks For Upcoming Project |  | 5d? | 2023-01-09 A | 2023-01-13 | 9 | 20% | 4d? | 17d |  |
| 12 | 2.1.5 | Establish and Confirm Risk Processes |  | 5d? | 2023-01-09 A | 2023-01-13 | 9 | 20% | 4d? | 17d |  |
| 13 | 2.1.6 | Confirm Upgrade Stage Ready To All Parties | milestone | 0d | 2023-01-13 A | 2023-01-13 A | 9 | 100% |  |  |  |
| 14 | 3 | **Future Proof Road Mapping** |  | 2d? | 2023-01-16 A | 2023-01-17 |  | 99% | 0d? |  |  |
| 15 | 3.1 | Establish and Confirm Status Upgrade Progress Reporting |  | 1d? | 2023-01-17 A | 2023-01-17 A | 13 | 100% |  |  |  |
| 16 | 3.2 | Company Employees Are Notified | milestone | 0d | 2023-01-16 | 2023-01-16 |  |  |  | 17d |  |
| 17 | 3.3 | Installation Standards Ready | milestone | 0d | 2023-01-19 A | 2023-01-19 A |  | 100% |  |  |  |
| 18 | 4 | **Cables and Cabling** |  | 6d? | 2023-01-20 A | 2023-01-27 |  | 14% | 5.14d? |  |  |
| 19 | 4.1 | Ensure 'Out Of Touch' Network Cabling |  | 5d? | 2023-01-20 A | 2023-01-26 | 17 | 20% | 4d? | 8d |  |
| 20 | 4.2 | Check Link Communication Requirements |  | 1d? | 2023-01-27 | 2023-01-27 |  |  |  | 7d | finish no earlier than 2023-01-27 |
| 21 | 4.3 | Daily Review Installation and Test |  | 1d? | 2023-01-20 | 2023-01-20 |  |  |  | 12d |  |
| 22 | 4.4 | Cabling Installtion Completed | milestone | 0d | 2023-01-27 A | 2023-01-27 A | 17 | 100% |  |  |  |
| 23 | 5 | **New Network Installaion** |  | 7d? | 2023-01-23 A | 2023-01-31 |  | 10% | 6.3d? |  |  |
| 24 | 5.1 | Pre-configure All Network Equipment |  | 6d? | 2023-01-23 A | 2023-01-30 | 22 | 17% | 5d? | 6d | finish no earlier than 2023-01-30 |
| 25 | 5.2 | Installation of Upgrade Network |  | 7d? | 2023-01-23 A | 2023-01-31 |  | 14% | 6d? | 5d |  |
| 26 | 5.3 | Dialy Review Installation and Test |  | 7d | 2023-01-23 | 2023-01-31 |  |  |  | 5d | start no earlier than 2023-01-23 |
| 27 | 5.4 | Inform Staff On Upgrade Processes |  | 10d? | 2023-01-23 A | 2023-02-03 | 22 | 10% | 9d? | 2d | finish no earlier than 2023-01-31 |
| 28 | 5.5 | Network Upgrade Complete | milestone | 0d | 2023-01-31 A | 2023-01-31 A | 22 | 100% |  |  |  |

Notes:
- 5: Make sure that time estimates for completing this work has been entered, and that a resource sheet has been created for those doing the work, and that a baseline has been set.
- 6: Collect any existing physical network diagrams that can help in the visualization of the current state of design. This can also help instantly identify routers, switch and computers models, location of LAN uplink bandwidth specification speeds, location of any network equipment cabinets and subsequent vital cooling information, and can also provide network cabling current standards, fibre and/or copper network cable. / Diagrams may also contain IP address information for the LAN including any virtual LANs information if more than a singular is enabled. Connectivity protocols used within the network infrastructure, any routing protocols used for connectivity to other LANs in other locations.
- 8: Meet with all businesses employees from every section of your company to fully understand any specific software and/or potential expansion requirements
- 14: Think 2 years for any advancement for each single location. Startups and small business companies may still require telecommunication or network cabinets. These cabinets can provide fibre or copper network cables to each employees workstation if the distance from the computer room exceeds allowable cable limits.
- 24: Beginning with computer room core switches first, provide secure connectivity to the servers. Dependent on the size of the network task it may be possible to immediately follow this by the installation of upgraded access layer switches.
- 25: Installations can make it easy to organize bandwidth allocations, making it easier to network architects to allow within the design emerging applications and technologies that require high-speed connections. High bandwidth cushions to guide against future growth storming, ensuring maximum connectivity for all your employees as your business expands over time, and allows divergence into new areas and equipment.
- 27: Inform all your employees of dates and times by the hour of how the implementation will effect them, as due to the implementation and uprading of any network infrastructure, various system access and subsequent data will be unavailable during these stages. This notification window will give all your employees an opportunity to plan any work around any resulting downtime they might experience.

| ID | WBS | Task | Type | Duration | Start | Finish | Predecessors | Total slack |
| --- | --- | --- | --- | --- | --- | --- | --- | --- |
| 29 | 6 | **Training and Mentoring** |  | 3d? | 2023-02-01 | 2023-02-03 |  |  |
| 30 | 6.1 | Train Staff on Changes to New Tools and Processes |  | 3d | 2023-02-01 | 2023-02-03 |  | 2d |
| 31 | 6.2 | Training & Mentoring complete | milestone | 0d | 2023-02-01 | 2023-02-01 |  | 5d |
| 32 | 7 | **Rollout** |  | 2d? | 2023-02-06 | 2023-02-07 |  |  |
| 33 | 7.1 | Hold a PMO Kick-Off Meeting |  | 1d? | 2023-02-06 | 2023-02-06 | 28 | 0d |
| 34 | 7.2 | Close out this plan |  | 1d? | 2023-02-07 | 2023-02-07 | 33 | 0d |
| 35 | 7.3 | New Network Running | milestone | 0d | 2023-02-07 | 2023-02-07 | 34 | 0d |

Notes:
- 30: Should we enable desktop firewalls when we have a firewall on our network'? Yes! employees will bring into the office a range of plugable devices from the outside, USB sticks, Phones, and they will plug them into their desktops to upload pictures and iTunes libraries to your server, an excellent gateway for viruses and Trojans.
