# Software Localization

Schedule from MS Project, 2024-01-04 to 2024-07-25.
Willcox PMO

## Calendars

- Standard: Mon-Fri 08:00-12:00, 13:00-17:00; Sat-Sun off.

## Resources

| Resource |
| --- |
| Management |
| Project manager |
| Analyst |
| International program manager |
| Translator |
| Localizer |
| Technical reviewer |
| Localization engineer |
| Project Manager HR Manager |
| Programmer |
| Support Engineer |
| CMO |

## Schedule

| ID | WBS | Task | Type | Duration | Start | Finish | Predecessors | Total slack | Resources | Work |
| --- | --- | --- | --- | --- | --- | --- | --- | --- | --- | --- |
| 1 | 1 | **Product Localization Template** |  | 25d | 2024-01-04 | 2024-02-07 |  | 0d |  | 240h |
| 2 | 1.1 | **Scope** |  | 25d | 2024-01-04 | 2024-02-07 |  | 0d |  | 240h |
| 3 | 1.1.1 | Review business case |  | 2d | 2024-01-04 | 2024-01-05 |  | 0d | Project manager; Management | 32h |
| 4 | 1.1.2 | Estimate project undertaking (for example, volumes, details/extent of localization) |  | 1w | 2024-01-08 | 2024-01-12 | 3 | 0d | Project manager | 40h |
| 5 | 1.1.3 | Prepare localization specification (feasibility, for markets) |  | 2d | 2024-01-15 | 2024-01-16 | 4 | 0d | Project manager | 16h |
| 6 | 1.1.4 | Estimate costs |  | 3d | 2024-01-17 | 2024-01-19 | 5 | 0d | Project manager | 24h |
| 7 | 1.1.5 | Identify risks |  | 2d | 2024-01-22 | 2024-01-23 | 6 | 0d | Project manager | 16h |
| 8 | 1.1.6 | Secure project sponsorship |  | 1d | 2024-01-24 | 2024-01-24 | 7 | 0d | Management | 8h |
| 9 | 1.1.7 | Define preliminary resources |  | 1w | 2024-01-25 | 2024-01-31 | 8 | 0d | Project manager | 40h |
| 10 | 1.1.8 | Define project communications matrix/methods |  | 3d | 2024-01-25 | 2024-01-29 | 8 | 7d | Project manager | 24h |
| 11 | 1.1.9 | Secure core resources |  | 1w | 2024-02-01 | 2024-02-07 | 9 | 0d | Project manager | 40h |
| 12 | 1.1.10 | Scope complete | milestone | 0d | 2024-02-07 | 2024-02-07 | 11, 10 | 0d |  |  |
| 14 | 2 | **Analysis/Planning** |  | 38d | 2024-02-08 | 2024-04-01 |  | 0d |  | 1108h |
| 15 | 2.1 | Identify localization resources (internal and outsourced) |  | 5d | 2024-02-08 | 2024-02-14 | 12 | 0d | Project Manager HR Manager | 40h |
| 16 | 2.2 | **Identify Components to be Localized** |  | 5d | 2024-02-15 | 2024-02-21 |  | 0d | Project Manager HR Manager | 420h |
| 17 | 2.2.1 | **Software Components** |  | 5d | 2024-02-15 | 2024-02-21 |  | 0d |  | 80h |
| 18 | 2.2.1.1 | Setup |  | 1w | 2024-02-15 | 2024-02-21 | 15 | 0d | Programmer | 40h |
| 19 | 2.2.1.2 | User interface |  | 1w | 2024-02-15 | 2024-02-21 | 15 | 0d | Programmer | 40h |
| 20 | 2.2.2 | **User Assistance Components** |  | 5d | 2024-02-15 | 2024-02-21 |  | 0d |  | 80h |
| 21 | 2.2.2.1 | Online help, documentation, frequently asked questions (FAQs) |  | 1w | 2024-02-15 | 2024-02-21 | 15 | 0d | Support Engineer | 40h |
| 22 | 2.2.2.2 | User guide |  | 1w | 2024-02-15 | 2024-02-21 | 15 | 0d | Support Engineer | 40h |
| 23 | 2.2.3 | **Marketing Components** |  | 5d | 2024-02-15 | 2024-02-21 |  | 0d |  | 120h |
| 24 | 2.2.3.1 | Packaging |  | 1w | 2024-02-15 | 2024-02-21 | 15 | 0d | CMO | 40h |
| 25 | 2.2.3.2 | Brochures |  | 1w | 2024-02-15 | 2024-02-21 | 15 | 0d | CMO | 40h |
| 26 | 2.2.3.3 | Web content |  | 1w | 2024-02-15 | 2024-02-21 | 15 | 0d | CMO | 40h |

Notes:
- 16: A variety of components need to be identified for your specific product's localization. We have provided a sampling to help you identify them. Keep in mind that each of these items can be further expanded to better reflect the scope of your project.

| ID | WBS | Task | Type | Duration | Start | Finish | Predecessors | Total slack | Free slack | Resources | Work |
| --- | --- | --- | --- | --- | --- | --- | --- | --- | --- | --- | --- |
| 27 | 2.2.4 | **Ancillary Components** |  | 5d | 2024-02-15 | 2024-02-21 |  | 0d |  |  | 100h |
| 28 | 2.2.4.1 | Macros |  | 0.5w | 2024-02-15 | 2024-02-19 | 15 | 2.5d |  | Project manager | 20h |
| 29 | 2.2.4.2 | Add-ins |  | 1w | 2024-02-15 | 2024-02-21 | 15 | 0d |  | Project manager | 40h |
| 30 | 2.2.4.3 | Templates |  | 1w | 2024-02-15 | 2024-02-21 | 15 | 0d |  | Project manager | 40h |
| 31 | 2.2.4.4 | Identify components to be localized complete | milestone | 0d | 2024-02-21 | 2024-02-21 | 30, 29, 28, 26, 24, 22, 21, 18, 19, 25 | 0d |  |  |  |
| 32 | 2.3 | Ensure file localizability |  | 1w | 2024-02-22 | 2024-02-28 | 31 | 0d |  | Project manager; Analyst; Localization engineer | 120h |
| 33 | 2.4 | Define localization processes |  | 2w | 2024-02-29 | 2024-03-13 | 32 | 0d |  | Project manager; Analyst; Localization engineer | 240h |
| 34 | 2.5 | Identify tools |  | 5d | 2024-02-29 | 2024-03-06 | 32 | 3d | 0d | Localization engineer; Analyst | 80h |
| 35 | 2.6 | Test tools |  | 2d | 2024-03-07 | 2024-03-08 | 34 | 3d |  | Localization engineer | 16h |
| 36 | 2.7 | Document localization process |  | 2d | 2024-03-14 | 2024-03-15 | 35, 33 | 0d |  | Localization engineer; Analyst | 32h |
| 37 | 2.8 | Prepare risk management plan |  | 3d | 2024-03-18 | 2024-03-20 | 33, 36 | 0d |  | International program manager; Project manager | 48h |
| 38 | 2.9 | Define communication procedures |  | 2d | 2024-03-21 | 2024-03-22 | 37 | 0.5d |  | Project manager; International program manager | 32h |
| 39 | 2.10 | Identify time constraints |  | 1d | 2024-03-21 | 2024-03-21 | 37 | 0d |  | Project manager; International program manager | 16h |
| 40 | 2.11 | Identify key milestones |  | 4h | 2024-03-22 | 2024-03-22 | 39 | 0d |  | Project manager; Analyst | 8h |
| 41 | 2.12 | Develop delivery timeline |  | 1d | 2024-03-22 | 2024-03-25 | 40 | 0d |  | Project manager | 8h |
| 42 | 2.13 | Obtain approvals to proceed (for example, concept, timeline, budget) |  | 4h | 2024-03-25 | 2024-03-25 | 41, 38 | 0d |  | Management; Project manager | 8h |
| 43 | 2.14 | Secure required resources |  | 1w | 2024-03-26 | 2024-04-01 | 42 | 0d |  | Project manager | 40h |
| 44 | 2.15 | Analysis complete | milestone | 0d | 2024-04-01 | 2024-04-01 | 43 | 0d |  |  |  |
| 46 | 3 | **Production** |  | 25d | 2024-04-02 | 2024-05-06 |  | 0d |  |  | 968h |
| 47 | 3.1 | **Software Components** |  | 11d | 2024-04-02 | 2024-04-16 |  | 3d |  |  | 128h |
| 48 | 3.1.1 | **Localization Component - Setup** |  | 11d | 2024-04-02 | 2024-04-16 |  | 14d |  |  | 64h |
| 49 | 3.1.1.1 | Review identified component functionality |  | 1d | 2024-04-02 | 2024-04-02 | 44 | 14d | 0d | Localizer | 8h |
| 50 | 3.1.1.2 | Localize identified component |  | 1w | 2024-04-03 | 2024-04-09 | 49 | 14d | 0d | Localizer | 40h |
| 51 | 3.1.1.3 | Refine component based on quality assurance (QA) feedback |  | 2d | 2024-04-12 | 2024-04-15 | 105 | 14d | 0d | Localizer | 16h |
| 52 | 3.1.1.4 | Localization component setup complete | milestone | 0d | 2024-04-16 | 2024-04-16 | 106 | 21d | 0d |  |  |

Notes:
- 46: Depending on your process, development and quality assurance may be iterative. In this template they are listed once, but these tasks can be copied and inserted as necessary to better reflect your process.

| ID | WBS | Task | Type | Duration | Start | Finish | Predecessors | Total slack | Free slack | Resources | Work |
| --- | --- | --- | --- | --- | --- | --- | --- | --- | --- | --- | --- |
| 53 | 3.1.2 | **Localization Component - User Interface** |  | 11d | 2024-04-02 | 2024-04-16 |  | 3d |  |  | 64h |
| 54 | 3.1.2.1 | Review identified component functionality |  | 1d | 2024-04-02 | 2024-04-02 | 44 | 3d | 0d | Localizer | 8h |
| 55 | 3.1.2.2 | Localize identified component |  | 1w | 2024-04-03 | 2024-04-09 | 54 | 3d | 0d | Localizer | 40h |
| 56 | 3.1.2.3 | Refine component based on QA feedback |  | 2d | 2024-04-12 | 2024-04-15 | 108 | 3d | 0d | Localizer | 16h |
| 57 | 3.1.2.4 | Localization component - user interface complete | milestone | 0d | 2024-04-16 | 2024-04-16 | 109 | 3d | 0d |  |  |
| 58 | 3.1.3 | Software components complete | milestone | 0d | 2024-04-16 | 2024-04-16 | 57 | 3d | 0d |  |  |
| 59 | 3.2 | **User Assistance Components** |  | 11d | 2024-04-17 | 2024-05-01 |  | 3d |  |  | 128h |
| 60 | 3.2.1 | **Localization Component - Online Help, Documentation, FAQs** |  | 11d | 2024-04-17 | 2024-05-01 |  | 3d |  |  | 64h |
| 61 | 3.2.1.1 | Review identified component functionality |  | 1d | 2024-04-17 | 2024-04-17 | 58 | 3d | 0d | Localizer | 8h |
| 62 | 3.2.1.2 | Localize identified component |  | 1w | 2024-04-18 | 2024-04-24 | 61 | 3d | 0d | Localizer | 40h |
| 63 | 3.2.1.3 | Refine component based on QA feedback |  | 2d | 2024-04-29 | 2024-04-30 | 111 | 3d | 0d | Localizer | 16h |
| 64 | 3.2.1.4 | Localization component - online help, documentation, FAQs complete | milestone | 0d | 2024-05-01 | 2024-05-01 | 112 | 10d | 0d |  |  |
| 65 | 3.2.2 | **Localization Component - User Guide** |  | 11d | 2024-04-17 | 2024-05-01 |  | 3d |  |  | 64h |
| 66 | 3.2.2.1 | Review identified component functionality |  | 1d | 2024-04-17 | 2024-04-17 | 58 | 3d | 0d | Localizer | 8h |
| 67 | 3.2.2.2 | Localize identified component |  | 1w | 2024-04-18 | 2024-04-24 | 66 | 3d | 0d | Localizer | 40h |
| 68 | 3.2.2.3 | Refine component based on QA feedback |  | 2d | 2024-04-29 | 2024-04-30 | 114 | 3d | 0d | Localizer | 16h |
| 69 | 3.2.2.4 | Localization component - user guide | milestone | 0d | 2024-05-01 | 2024-05-01 | 115 | 10d | 0d |  |  |
| 70 | 3.2.3 | User assistance components complete | milestone | 0d | 2024-05-01 | 2024-05-01 | 69 | 61d |  |  |  |
| 71 | 3.3 | **Marketing Components** |  | 25d | 2024-04-02 | 2024-05-06 |  | 0d |  |  | 712h |
| 72 | 3.3.1 | **Localization Component - Marketing Materials** |  | 11d | 2024-04-02 | 2024-04-16 |  | 3d |  |  | 128h |
| 73 | 3.3.1.1 | Review identified component functionality |  | 1d | 2024-04-02 | 2024-04-02 | 44 | 3d | 0d | Localizer; Translator | 16h |
| 74 | 3.3.1.2 | Localize identified component |  | 1w | 2024-04-03 | 2024-04-09 | 73 | 3d | 0d | Localizer; Translator | 80h |
| 75 | 3.3.1.3 | Refine component based on QA feedback |  | 2d | 2024-04-12 | 2024-04-15 | 117 | 3d | 0d | Localizer; Translator | 32h |
| 76 | 3.3.1.4 | Localization component marketing materials complete | milestone | 0d | 2024-04-16 | 2024-04-16 | 75, 118 | 3d | 0d |  |  |

| ID | WBS | Task | Type | Duration | Start | Finish | Predecessors | Total slack | Free slack | Resources | Work |
| --- | --- | --- | --- | --- | --- | --- | --- | --- | --- | --- | --- |
| 77 | 3.3.2 | **Localization Component - Web Content** |  | 11d | 2024-04-17 | 2024-05-01 |  | 3d |  |  | 128h |
| 78 | 3.3.2.1 | Review identified component functionality |  | 1d | 2024-04-17 | 2024-04-17 | 76 | 3d | 0d | Localizer; Translator | 16h |
| 79 | 3.3.2.2 | Localize identified component |  | 1w | 2024-04-18 | 2024-04-24 | 78 | 3d | 0d | Localizer; Translator | 80h |
| 80 | 3.3.2.3 | Refine component based on QA feedback |  | 2d | 2024-04-29 | 2024-04-30 | 120 | 3d | 0d | Localizer; Translator | 32h |
| 81 | 3.3.2.4 | Localization component - web content | milestone | 0d | 2024-05-01 | 2024-05-01 | 80, 121 | 10d | 0d |  |  |
| 82 | 3.3.3 | Marketing components complete | milestone | 0d | 2024-05-01 | 2024-05-01 | 81 | 61d |  |  |  |
| 83 | 3.3.4 | **Ancillary Components** |  | 25d | 2024-04-02 | 2024-05-06 |  | 0d |  |  | 456h |
| 84 | 3.3.4.1 | **Localization Component - Macros** |  | 11d | 2024-04-02 | 2024-04-16 |  | 0d |  |  | 128h |
| 85 | 3.3.4.1.1 | Review identified component functionality |  | 1d | 2024-04-02 | 2024-04-02 | 44 | 0d |  | Localizer; Translator | 16h |
| 86 | 3.3.4.1.2 | Localize identified component |  | 1w | 2024-04-03 | 2024-04-09 | 85 | 0d |  | Localizer; Translator | 80h |
| 87 | 3.3.4.1.3 | Refine component based on QA feedback |  | 2d | 2024-04-12 | 2024-04-15 | 123 | 0d |  | Localizer; Translator | 32h |
| 88 | 3.3.4.1.4 | Localization component - macros | milestone | 0d | 2024-04-16 | 2024-04-16 | 124 | 0d |  |  |  |
| 89 | 3.3.4.2 | **Localization Component - Add-Ins** |  | 11d | 2024-04-17 | 2024-05-01 |  | 0d |  |  | 128h |
| 90 | 3.3.4.2.1 | Review identified component functionality |  | 1d | 2024-04-17 | 2024-04-17 | 88 | 0d |  | Localizer; Translator | 16h |
| 91 | 3.3.4.2.2 | Localize identified component |  | 1w | 2024-04-18 | 2024-04-24 | 90 | 0d |  | Localizer; Translator | 80h |
| 92 | 3.3.4.2.3 | Refine component based on QA feedback |  | 2d | 2024-04-29 | 2024-04-30 | 126 | 0d |  | Localizer; Translator | 32h |
| 93 | 3.3.4.2.4 | Localization component - add-ins | milestone | 0d | 2024-05-01 | 2024-05-01 | 127 | 0d |  |  |  |
| 94 | 3.3.4.3 | **Localization Component - Templates** |  | 11d | 2024-04-02 | 2024-04-16 |  | 11d |  |  | 128h |
| 95 | 3.3.4.3.1 | Review identified component functionality |  | 1d | 2024-04-02 | 2024-04-02 | 44 | 11d | 0d | Localizer; Translator | 16h |
| 96 | 3.3.4.3.2 | Localize identified component |  | 1w | 2024-04-03 | 2024-04-09 | 95 | 11d | 0d | Localizer; Translator | 80h |
| 97 | 3.3.4.3.3 | Refine component based on QA feedback |  | 2d | 2024-04-12 | 2024-04-15 | 129 | 11d | 0d | Localizer; Translator | 32h |
| 98 | 3.3.4.3.4 | Localization component - templates | milestone | 0d | 2024-04-16 | 2024-04-16 | 130 | 11d | 0d |  |  |
| 99 | 3.3.4.4 | Ancillary components complete | milestone | 0d | 2024-05-01 | 2024-05-01 | 93 | 0d |  |  |  |
| 100 | 3.3.4.5 | Validate final released software (decisions on development cycle) |  | 3d | 2024-05-02 | 2024-05-06 | 99, 98 | 0d |  | Project manager; International program manager; Management | 72h |
| 101 | 3.3.5 | Development complete | milestone | 0d | 2024-05-06 | 2024-05-06 | 99, 98, 100 | 8d |  |  |  |

Notes:
- 100: This template assumes that code complete occurs before localization. If the code is not complete before localization in your project, you will need to evaluate how to incorporate changes from ongoing change cycles as code becomes complete.

| ID | WBS | Task | Duration | Start | Finish | Predecessors | Total slack | Free slack | Resources | Work |
| --- | --- | --- | --- | --- | --- | --- | --- | --- | --- | --- |
| 103 | 4 | **Quality Assurance** | 77d | 2024-04-10 | 2024-07-25 |  | 0d |  |  | 1136h |
| 104 | 4.1 | **Localization Component - Setup** | 5d | 2024-04-10 | 2024-04-16 |  | 14d |  |  | 24h |
| 105 | 4.1.1 | Test component - setup | 2d | 2024-04-10 | 2024-04-11 | 50 | 14d | 0d | Technical reviewer | 16h |
| 106 | 4.1.2 | QA review cycle | 1d | 2024-04-16 | 2024-04-16 | 51 | 14d | 0d | Technical reviewer | 8h |
| 107 | 4.2 | **Localization Component - User Interface** | 5d | 2024-04-10 | 2024-04-16 |  | 3d |  |  | 24h |
| 108 | 4.2.1 | Test component - user interface | 2d | 2024-04-10 | 2024-04-11 | 55 | 3d | 0d | Technical reviewer | 16h |
| 109 | 4.2.2 | QA review cycle | 1d | 2024-04-16 | 2024-04-16 | 56 | 3d | 0d | Technical reviewer | 8h |
| 110 | 4.3 | **Localization Component - Online Help, Documentation, FAQs** | 5d | 2024-04-25 | 2024-05-01 |  | 3d |  |  | 24h |
| 111 | 4.3.1 | Test component - online help, documentation, FAQs | 2d | 2024-04-25 | 2024-04-26 | 62 | 3d | 0d | Technical reviewer | 16h |
| 112 | 4.3.2 | QA review cycle | 1d | 2024-05-01 | 2024-05-01 | 63 | 3d | 0d | Technical reviewer | 8h |
| 113 | 4.4 | **Localization Component - User Guide** | 5d | 2024-04-25 | 2024-05-01 |  | 3d |  |  | 24h |
| 114 | 4.4.1 | Test component - user guide | 2d | 2024-04-25 | 2024-04-26 | 67 | 3d | 0d | Technical reviewer | 16h |
| 115 | 4.4.2 | QA review cycle | 1d | 2024-05-01 | 2024-05-01 | 68 | 3d | 0d | Technical reviewer | 8h |
| 116 | 4.5 | **Localization Component - Marketing Materials** | 5d | 2024-04-10 | 2024-04-16 |  | 3d |  |  | 24h |
| 117 | 4.5.1 | Test component - marketing materials | 2d | 2024-04-10 | 2024-04-11 | 74 | 3d | 0d | Technical reviewer | 16h |
| 118 | 4.5.2 | QA review cycle | 1d | 2024-04-16 | 2024-04-16 | 75 | 3d | 0d | Technical reviewer | 8h |
| 119 | 4.6 | **Localization Component - Web Content** | 5d | 2024-04-25 | 2024-05-01 |  | 3d |  |  | 24h |
| 120 | 4.6.1 | Test component - web content | 2d | 2024-04-25 | 2024-04-26 | 79 | 3d | 0d | Technical reviewer | 16h |
| 121 | 4.6.2 | QA review cycle | 1d | 2024-05-01 | 2024-05-01 | 80 | 3d | 0d | Technical reviewer | 8h |
| 122 | 4.7 | **Localization Component - Macros** | 5d | 2024-04-10 | 2024-04-16 |  | 0d |  |  | 24h |
| 123 | 4.7.1 | Test component - macros | 2d | 2024-04-10 | 2024-04-11 | 86 | 0d |  | Technical reviewer | 16h |
| 124 | 4.7.2 | QA review cycle | 1d | 2024-04-16 | 2024-04-16 | 87 | 0d |  | Technical reviewer | 8h |
| 125 | 4.8 | **Localization Component - Add-Ins** | 5d | 2024-04-25 | 2024-05-01 |  | 0d |  |  | 24h |
| 126 | 4.8.1 | Test component - add-ins | 2d | 2024-04-25 | 2024-04-26 | 91 | 0d |  | Technical reviewer | 16h |
| 127 | 4.8.2 | QA review cycle | 1d | 2024-05-01 | 2024-05-01 | 92 | 0d |  | Technical reviewer | 8h |

| ID | WBS | Task | Type | Duration | Start | Finish | Predecessors | Total slack | Free slack | Resources | Work |
| --- | --- | --- | --- | --- | --- | --- | --- | --- | --- | --- | --- |
| 128 | 4.9 | **Localization Component - Templates** |  | 5d | 2024-04-10 | 2024-04-16 |  | 11d |  |  | 24h |
| 129 | 4.9.1 | Test component - templates |  | 2d | 2024-04-10 | 2024-04-11 | 96 | 11d | 0d | Technical reviewer | 16h |
| 130 | 4.9.2 | QA review cycle |  | 1d | 2024-04-16 | 2024-04-16 | 97 | 11d | 0d | Technical reviewer | 8h |
| 131 | 4.10 | **Integration Testing** |  | 7d | 2024-05-07 | 2024-05-15 |  | 0d |  |  | 56h |
| 132 | 4.10.1 | Full component test |  | 1w | 2024-05-07 | 2024-05-13 | 130, 127, 124, 121, 118, 115, 112, 109, 106, 100 | 0d |  | Technical reviewer | 40h |
| 133 | 4.10.2 | QA review cycle |  | 2d | 2024-05-14 | 2024-05-15 | 132 | 0d |  | Technical reviewer | 16h |
| 134 | 4.11 | **Sponsor Review** |  | 22d | 2024-04-17 | 2024-05-16 |  | 0d |  |  | 160h |
| 135 | 4.11.1 | Review component - setup |  | 1d | 2024-04-17 | 2024-04-17 | 52 | 21d |  | Management; International program manager | 16h |
| 136 | 4.11.2 | Review component - user interface |  | 1d | 2024-04-17 | 2024-04-17 | 57 | 21d |  | Management; International program manager | 16h |
| 137 | 4.11.3 | Review component - online help, documentation, FAQs |  | 1d | 2024-05-02 | 2024-05-02 | 64 | 10d |  | Management; International program manager | 16h |
| 138 | 4.11.4 | Review component - user guide |  | 1d | 2024-05-02 | 2024-05-02 | 69 | 10d |  | Management; International program manager | 16h |
| 139 | 4.11.5 | Review component - marketing materials |  | 1d | 2024-04-17 | 2024-04-17 | 76 | 21d |  | Management; International program manager | 16h |
| 140 | 4.11.6 | Review component - web content |  | 1d | 2024-05-02 | 2024-05-02 | 81 | 10d |  | Management; International program manager | 16h |
| 141 | 4.11.7 | Review component - macros |  | 1d | 2024-04-17 | 2024-04-17 | 88 | 21d |  | Management; International program manager | 16h |
| 142 | 4.11.8 | Review component - add-ins |  | 1d | 2024-05-02 | 2024-05-02 | 93 | 10d |  | Management; International program manager | 16h |
| 143 | 4.11.9 | Review component - templates |  | 1d | 2024-04-17 | 2024-04-17 | 98 | 21d |  | Management; International program manager | 16h |
| 144 | 4.11.10 | Review integrated product |  | 1d | 2024-05-16 | 2024-05-16 | 133 | 0d |  | Management; International program manager | 16h |
| 145 | 4.12 | Quality assurance complete | milestone | 0d | 2024-05-16 | 2024-05-16 | 135, 136, 137, 138, 139, 140, 141, 142, 143, 144 | 0d |  |  |  |
| 146 | 4.13 | **Beta Testing** |  | 33d | 2024-05-17 | 2024-07-02 |  | 0d |  |  | 568h |
| 147 | 4.13.1 | Disseminate completed product |  | 3d | 2024-05-17 | 2024-05-21 | 101, 145 | 0d |  | Management; International program manager | 48h |
| 148 | 4.13.2 | Obtain feedback |  | 4w | 2024-05-22 | 2024-06-18 | 147 | 0d |  | Management; International program manager | 320h |
| 149 | 4.13.3 | Modify |  | 1w | 2024-06-19 | 2024-06-25 | 148 | 0d |  | Management; International program manager; Localization engineer | 120h |
| 150 | 4.13.4 | Test |  | 1w | 2024-06-26 | 2024-07-02 | 149 | 0d |  | Management; International program manager | 80h |
| 151 | 4.13.5 | Complete | milestone | 0d | 2024-07-02 | 2024-07-02 | 150 | 0d |  |  |  |

| ID | WBS | Task | Type | Duration | Start | Finish | Predecessors | Total slack | Resources | Work |
| --- | --- | --- | --- | --- | --- | --- | --- | --- | --- | --- |
| 152 | 4.14 | **Post-Project Review** |  | 17d | 2024-07-03 | 2024-07-25 |  | 0d |  | 136h |
| 153 | 4.14.1 | Review project information |  | 1w | 2024-07-03 | 2024-07-09 | 151 | 0d | Project manager | 40h |
| 154 | 4.14.2 | Finalize cost analysis |  | 3d | 2024-07-10 | 2024-07-12 | 153 | 0d | Project manager | 24h |
| 155 | 4.14.3 | Analyze performance |  | 3d | 2024-07-15 | 2024-07-17 | 154 | 0d | Project manager | 24h |
| 156 | 4.14.4 | Archive files |  | 2d | 2024-07-18 | 2024-07-19 | 155 | 0d | Project manager | 16h |
| 157 | 4.14.5 | Document lessons learned |  | 2d | 2024-07-22 | 2024-07-23 | 156 | 0d | Project manager | 16h |
| 158 | 4.14.6 | Distribute to team members |  | 2d | 2024-07-24 | 2024-07-25 | 157 | 0d | Project manager | 16h |
| 159 | 4.14.7 | Post-project review complete | milestone | 0d | 2024-07-25 | 2024-07-25 | 158 | 0d |  |  |
